# Plan PRs

How a schedule from MS Project changed from version to version. A marks actual dates.

## Version 1 (saved 2006-10-06, file 20061005-1160103422.mpp)

| ID | WBS | Task | Duration | Start | Finish | Predecessors | Total float | Constraint |
| --- | --- | --- | --- | --- | --- | --- | --- | --- |
| 1 | 1 | **Foto XS - PR´s** | 61.75d | 2006-09-05 08:00 | 2006-11-30 15:00 |  | 0d |  |
| 2 | 1.1 | **Configuración y Desarrollo** | 61.75d | 2006-09-05 08:00 | 2006-11-30 15:00 |  | 0d |  |
| 3 |  | PR 329 | 0.25d | 2006-09-05 08:00 | 2006-09-05 10:00 |  | 58.5d | start no earlier than 2006-09-05 08:00 |
| 4 |  | PR 87 | 0.25d | 2006-09-05 08:00 | 2006-09-05 10:00 |  | 58.5d | start no earlier than 2006-09-05 08:00 |
| 5 |  | PR 259 | 0.25d | 2006-09-05 08:00 | 2006-09-05 10:00 |  | 58.5d | start no earlier than 2006-09-05 08:00 |
| 6 |  | PR 276 | 0.25d | 2006-09-05 08:00 | 2006-09-05 10:00 |  | 58.5d | start no earlier than 2006-09-05 08:00 |
| 7 |  | PR 304 | 0.25d | 2006-09-06 08:00 | 2006-09-06 10:00 |  | 57.5d | start no earlier than 2006-09-06 08:00 |
| 8 |  | PR 337 | 0.5d | 2006-09-06 08:00 | 2006-09-06 12:00 |  | 57.25d | start no earlier than 2006-09-06 08:00 |
| 9 |  | PR 256 | 0.5d | 2006-09-06 08:00 | 2006-09-06 12:00 |  | 57.25d | start no earlier than 2006-09-06 08:00 |
| 10 |  | PR 22 | 0.25d | 2006-09-07 08:00 | 2006-09-07 10:00 |  | 56.5d | start no earlier than 2006-09-07 08:00 |
| 11 |  | PR 59 | 0.25d | 2006-09-07 08:00 | 2006-09-07 10:00 |  | 56.5d | start no earlier than 2006-09-07 08:00 |
| 12 |  | PR 5 | 0.25d | 2006-09-07 08:00 | 2006-09-07 10:00 |  | 56.5d | start no earlier than 2006-09-07 08:00 |
| 13 |  | PR 278 | 1d | 2006-09-08 08:00 | 2006-09-08 17:00 |  | 54.75d | start no earlier than 2006-09-08 08:00 |
| 14 |  | PR 240 | 0.5d | 2006-09-11 08:00 | 2006-09-11 12:00 |  | 54.25d | start no earlier than 2006-09-11 08:00 |
| 15 |  | PR 258 | 0.5d | 2006-09-11 08:00 | 2006-09-11 12:00 |  | 54.25d | start no earlier than 2006-09-11 08:00 |
| 16 |  | PR 268 | 0.75d | 2006-09-13 08:00 | 2006-09-13 15:00 |  | 52d | start no earlier than 2006-09-13 08:00 |
| 17 |  | PR 7 | 0.5d | 2006-09-14 08:00 | 2006-09-14 12:00 |  | 51.25d | start no earlier than 2006-09-14 08:00 |
| 18 |  | PR 89 | 0.5d | 2006-09-15 08:00 | 2006-09-15 12:00 |  | 50.25d | start no earlier than 2006-09-15 08:00 |
| 19 |  | PR 17 | 0.75d | 2006-09-18 08:00 | 2006-09-18 15:00 |  | 49d | start no earlier than 2006-09-18 08:00 |
| 20 |  | PR 372 | 8d | 2006-09-18 08:00 | 2006-09-27 17:00 |  | 41.75d | start no earlier than 2006-09-18 08:00 |
| 21 |  | PR 241 | 0.5d | 2006-09-19 08:00 | 2006-09-19 12:00 |  | 48.25d | start no earlier than 2006-09-19 08:00 |
| 22 |  | PR 94 | 0.25d | 2006-09-19 08:00 | 2006-09-19 10:00 |  | 48.5d | start no earlier than 2006-09-19 08:00 |
| 23 |  | PR 280 | 0.25d | 2006-09-20 08:00 | 2006-09-20 10:00 |  | 47.5d | start no earlier than 2006-09-20 08:00 |
| 24 |  | PR 96 | 0.25d | 2006-09-20 08:00 | 2006-09-20 10:00 |  | 47.5d | start no earlier than 2006-09-20 08:00 |
| 25 |  | PR 103 | 1.5d | 2006-09-21 08:00 | 2006-09-22 12:00 |  | 45.25d | start no earlier than 2006-09-21 08:00 |
| 26 |  | PR 10 | 0.5d | 2006-09-22 08:00 | 2006-09-22 12:00 |  | 45.25d | start no earlier than 2006-09-22 08:00 |
| 27 |  | PR 193 | 0.25d | 2006-09-26 08:00 | 2006-09-26 10:00 |  | 43.5d | start no earlier than 2006-09-26 08:00 |
| 28 |  | PR 273 | 0.25d | 2006-10-13 08:00 | 2006-10-13 10:00 |  | 0d | start no earlier than 2006-10-13 08:00 |
| 29 |  | PR 102 | 0.25d | 2006-10-13 10:00 | 2006-10-13 12:00 | 28 | 0d |  |
| 30 |  | PR 18 | 0.5d | 2006-10-13 13:00 | 2006-10-13 17:00 | 29 | 0d |  |
| 31 |  | PR 21 | 0.25d | 2006-10-16 08:00 | 2006-10-16 10:00 | 30 | 0d |  |
| 32 |  | PR 3 | 10d | 2006-10-16 10:00 | 2006-10-30 10:00 | 31 | 0d |  |
| 33 |  | PR 62 | 1d | 2006-10-30 10:00 | 2006-10-31 10:00 | 32 | 0d |  |
| 34 |  | PR 106 | 0.5d | 2006-10-31 10:00 | 2006-10-31 15:00 | 33 | 0d |  |
| 35 |  | PR 98 | 1d | 2006-10-31 15:00 | 2006-11-01 15:00 | 34 | 0d |  |
| 36 |  | PR 90 | 0.5d | 2006-11-01 15:00 | 2006-11-02 10:00 | 35 | 0d |  |
| 37 |  | PR 15 | 1d | 2006-11-02 10:00 | 2006-11-03 10:00 | 36 | 0d |  |
| 38 |  | PR 261 | 0.5d | 2006-11-03 10:00 | 2006-11-03 15:00 | 37 | 0d |  |
| 39 |  | PR 12 (331) | 1d | 2006-11-03 15:00 | 2006-11-06 15:00 | 38 | 0d |  |
| 40 |  | PR 377 | 1d | 2006-11-06 15:00 | 2006-11-07 15:00 | 39 | 0d |  |
| 41 |  | PR 117 | 1d | 2006-11-07 15:00 | 2006-11-08 15:00 | 40 | 0d |  |
| 42 |  | PR 331 | 0.5d | 2006-11-08 15:00 | 2006-11-09 10:00 | 41 | 0d |  |
| 43 |  | PR 185 | 1d | 2006-11-09 10:00 | 2006-11-10 10:00 | 42 | 0d |  |
| 44 |  | PR 14 (3) | 10d | 2006-11-10 10:00 | 2006-11-24 10:00 | 43 | 0d |  |
| 45 |  | PR 153 | 0.5d | 2006-11-24 10:00 | 2006-11-24 15:00 | 44 | 0d |  |
| 46 |  | PR 8 | 1d | 2006-11-24 15:00 | 2006-11-27 15:00 | 45 | 0d |  |
| 47 |  | PR 175 | 1d | 2006-11-27 15:00 | 2006-11-28 15:00 | 46 | 0d |  |
| 48 |  | Ajustes recomendados | 2d | 2006-11-28 15:00 | 2006-11-30 15:00 | 47 | 0d |  |
| 49 | 1.2 | **Gerencia de Proyecto** | 57.5d | 2006-09-11 08:00 | 2006-11-30 12:00 |  | 0.25d |  |
| 50 |  | Planificación | 15d | 2006-09-12 08:00 | 2006-10-02 17:00 |  | 41.75d | start no earlier than 2006-09-12 08:00 |
| 51 | 1.2.2 | **Control y Seguimiento** | 57.25d | 2006-09-11 08:00 | 2006-11-30 10:00 |  | 0.5d |  |
| 52 |  | 11-09 | 0.25d | 2006-09-11 08:00 | 2006-09-11 10:00 |  | 57.5d | start no earlier than 2006-09-11 08:00 |
| 53 |  | 05-10 | 0.25d | 2006-10-05 08:00 | 2006-10-05 10:00 |  | 39.5d | start no earlier than 2006-10-05 08:00 |
| 54 |  | 11-10 | 0.25d | 2006-10-11 08:00 | 2006-10-11 10:00 |  | 35.5d | start no earlier than 2006-10-11 08:00 |
| 55 |  | 19-10 | 0.25d | 2006-10-19 08:00 | 2006-10-19 10:00 |  | 30.5d | start no earlier than 2006-10-19 08:00 |
| 56 |  | 26-10 | 0.25d | 2006-10-26 08:00 | 2006-10-26 10:00 |  | 25.5d | start no earlier than 2006-10-26 08:00 |
| 57 |  | 02-11 | 0.25d | 2006-11-02 08:00 | 2006-11-02 10:00 |  | 20.5d | start no earlier than 2006-11-02 08:00 |
| 58 |  | 09-11 | 0.25d | 2006-11-09 08:00 | 2006-11-09 10:00 |  | 15.5d | start no earlier than 2006-11-09 08:00 |
| 59 |  | 16-11 | 0.25d | 2006-11-16 08:00 | 2006-11-16 10:00 |  | 10.5d | start no earlier than 2006-11-16 08:00 |
| 60 |  | 23-11 | 0.25d | 2006-11-23 08:00 | 2006-11-23 10:00 |  | 5.5d | start no earlier than 2006-11-23 08:00 |
| 61 |  | 30-11 | 0.25d | 2006-11-30 08:00 | 2006-11-30 10:00 |  | 0.5d | start no earlier than 2006-11-30 08:00 |
| 62 |  | Cierre | 0.5d | 2006-11-30 08:00 | 2006-11-30 12:00 |  | 0.25d | start no earlier than 2006-11-30 08:00 |

## Version 2 (saved 2006-10-31, file 20061031-1162300049.mpp)

Last finish 2006-11-30 → 2006-11-16 (-14d). Complete tasks 0 → 33.

Added:

| ID | Task | Duration | Start | Finish | Predecessors | Constraint | Resources |
| --- | --- | --- | --- | --- | --- | --- | --- |
| 30 | PR 93 | 1d | 2006-10-25 08:00 A | 2006-10-25 17:00 A | 29 |  | Gustavo |
| 32 | PR 14 | 1d | 2006-10-19 08:00 A | 2006-10-19 17:00 A | 31 |  | Gustavo |
| 54 | 30-10 | 0.5d | 2006-10-30 08:00 | 2006-10-30 12:00 |  | start no earlier than 2006-10-30 08:00 | Gustavo [25%]; Kathy [25%]; Listbeth [25%] |

Removed: 33 PR 62; 37 PR 15; 39 PR 12 (331); 40 PR 377; 42 PR 331; 44 PR 14 (3); 47 PR 175; 59 16-11; 60 23-11; 61 30-11

Changed:

| ID | Task | Start | Finish | Duration | Complete | Total float | Predecessors | Other |
| --- | --- | --- | --- | --- | --- | --- | --- | --- |
| 1 | **Foto XS - PR´s** | 2006-09-05 08:00 A | 2006-11-30 15:00 → 2006-11-16 17:00 (-14d) | 61.75d → 52d | 0% → 47% |  |  | baseline start none → 2006-09-05 08:00; baseline finish none → 2006-11-16 17:00 |
| 2 | **Configuración y Desarrollo** | 2006-09-05 08:00 A | 2006-11-30 15:00 → 2006-11-09 17:00 (-21d) | 61.75d → 47d | 0% → 76% |  |  | baseline start none → 2006-09-05 08:00; baseline finish none → 2006-11-09 17:00 |
| 3 | PR 329 | 2006-09-05 08:00 A | 2006-09-05 10:00 A |  | 0% → 100% | 58.5d → none |  | baseline start none → 2006-09-05 08:00; baseline finish none → 2006-09-05 10:00 |
| 4 | PR 87 | 2006-09-05 08:00 A | 2006-09-05 10:00 A |  | 0% → 100% | 58.5d → none |  | baseline start none → 2006-09-05 08:00; baseline finish none → 2006-09-05 10:00 |
| 5 | PR 259 | 2006-09-05 08:00 A | 2006-09-05 10:00 A |  | 0% → 100% | 58.5d → none |  | baseline start none → 2006-09-05 08:00; baseline finish none → 2006-09-05 10:00 |
| 6 | PR 276 | 2006-09-05 08:00 A | 2006-09-05 10:00 A |  | 0% → 100% | 58.5d → none |  | baseline start none → 2006-09-05 08:00; baseline finish none → 2006-09-05 10:00 |
| 7 | PR 304 | 2006-09-06 08:00 A | 2006-09-06 10:00 A |  | 0% → 100% | 57.5d → none |  | baseline start none → 2006-09-06 08:00; baseline finish none → 2006-09-06 10:00 |
| 8 | PR 337 | 2006-09-06 08:00 A | 2006-09-06 12:00 A |  | 0% → 100% | 57.25d → none |  | baseline start none → 2006-09-06 08:00; baseline finish none → 2006-09-06 12:00 |
| 9 | PR 256 | 2006-09-06 08:00 A | 2006-09-06 12:00 A |  | 0% → 100% | 57.25d → none |  | baseline start none → 2006-09-06 08:00; baseline finish none → 2006-09-06 12:00 |
| 10 | PR 22 | 2006-09-07 08:00 A | 2006-09-07 10:00 A |  | 0% → 100% | 56.5d → none |  | baseline start none → 2006-09-07 08:00; baseline finish none → 2006-09-07 10:00 |
| 11 | PR 59 | 2006-09-07 08:00 A | 2006-09-07 10:00 A |  | 0% → 100% | 56.5d → none |  | baseline start none → 2006-09-07 08:00; baseline finish none → 2006-09-07 10:00 |
| 12 | PR 5 | 2006-09-07 08:00 A | 2006-09-07 10:00 A |  | 0% → 100% | 56.5d → none |  | baseline start none → 2006-09-07 08:00; baseline finish none → 2006-09-07 10:00 |
| 13 | PR 278 | 2006-09-08 08:00 A | 2006-09-08 17:00 A |  | 0% → 100% | 54.75d → none |  | baseline start none → 2006-09-08 08:00; baseline finish none → 2006-09-08 17:00 |
| 14 | PR 240 | 2006-09-11 08:00 A | 2006-09-11 12:00 A |  | 0% → 100% | 54.25d → none |  | baseline start none → 2006-09-11 08:00; baseline finish none → 2006-09-11 12:00 |
| 15 | PR 258 | 2006-09-11 08:00 A | 2006-09-11 12:00 A |  | 0% → 100% | 54.25d → none |  | baseline start none → 2006-09-11 08:00; baseline finish none → 2006-09-11 12:00 |
| 16 | PR 268 | 2006-09-13 08:00 A | 2006-09-13 15:00 A |  | 0% → 100% | 52d → none |  | baseline start none → 2006-09-13 08:00; baseline finish none → 2006-09-13 15:00 |
| 17 | PR 7 | 2006-09-14 08:00 A | 2006-09-14 12:00 A |  | 0% → 100% | 51.25d → none |  | baseline start none → 2006-09-14 08:00; baseline finish none → 2006-09-14 12:00 |
| 18 | PR 89 | 2006-09-15 08:00 A | 2006-09-15 12:00 A |  | 0% → 100% | 50.25d → none |  | baseline start none → 2006-09-15 08:00; baseline finish none → 2006-09-15 12:00 |
| 19 | PR 17 | 2006-09-18 08:00 A | 2006-09-18 15:00 A |  | 0% → 100% | 49d → none |  | baseline start none → 2006-09-18 08:00; baseline finish none → 2006-09-18 15:00 |
| 20 | PR 372 | 2006-09-18 08:00 A | 2006-09-27 17:00 A |  | 0% → 100% | 41.75d → none |  | baseline start none → 2006-09-18 08:00; baseline finish none → 2006-09-27 17:00 |
| 21 | PR 94 | 2006-09-19 08:00 A | 2006-09-19 10:00 A |  | 0% → 100% | 48.5d → none |  | baseline start none → 2006-09-19 08:00; baseline finish none → 2006-09-19 10:00 |
| 22 | PR 280 | 2006-09-20 08:00 A | 2006-09-20 10:00 A |  | 0% → 100% | 47.5d → none |  | baseline start none → 2006-09-20 08:00; baseline finish none → 2006-09-20 10:00 |
| 23 | PR 96 | 2006-09-20 08:00 A | 2006-09-20 10:00 A |  | 0% → 100% | 47.5d → none |  | baseline start none → 2006-09-20 08:00; baseline finish none → 2006-09-20 10:00 |
| 24 | PR 103 | 2006-09-21 08:00 A | 2006-09-22 12:00 A |  | 0% → 100% | 45.25d → none |  | baseline start none → 2006-09-21 08:00; baseline finish none → 2006-09-22 12:00 |
| 25 | PR 10 | 2006-09-22 08:00 A | 2006-09-22 12:00 A |  | 0% → 100% | 45.25d → none |  | resources Gustavo → none; baseline start none → 2006-09-22 08:00; baseline finish none → 2006-09-22 12:00 |
| 26 | PR 193 | 2006-09-26 08:00 A | 2006-09-26 10:00 A |  | 0% → 100% | 43.5d → none |  | baseline start none → 2006-09-26 08:00; baseline finish none → 2006-09-26 10:00 |
| 27 | PR 117 | 2006-11-07 15:00 → 2006-10-09 08:00 A (-29d) | 2006-11-08 15:00 → 2006-10-10 17:00 A (-29d) | 1d → 2d | 0% → 100% | 0d → none | PR 377 → none | constraint none → start no earlier than 2006-10-09 08:00; resources Gustavo → Gustavo [50%]; baseline start none → 2006-10-09 08:00; baseline finish none → 2006-10-10 17:00 |
| 28 | PR 273 | 2006-10-13 08:00 → 2006-10-11 08:00 A (-2d) | 2006-10-13 10:00 → 2006-10-11 17:00 A (-2d) | 0.25d → 1d | 0% → 100% | 0d → none | none → 27 | constraint start no earlier than 2006-10-13 08:00 → none; baseline start none → 2006-10-11 08:00; baseline finish none → 2006-10-11 17:00 |
| 29 | PR 102 | 2006-10-13 10:00 → 2006-10-17 08:00 A (+4d) | 2006-10-13 12:00 → 2006-10-17 17:00 A (+4d) | 0.25d → 1d | 0% → 100% | 0d → none |  | baseline start none → 2006-10-17 08:00; baseline finish none → 2006-10-17 17:00 |
| 31 | PR 185 | 2006-11-09 10:00 → 2006-10-18 08:00 A (-22d) | 2006-11-10 10:00 → 2006-10-18 17:00 A (-23d) |  | 0% → 100% | 0d → none | PR 331 → 30 | baseline start none → 2006-10-18 08:00; baseline finish none → 2006-10-18 17:00 |
| 33 | PR 21 | 2006-10-16 08:00 → 2006-11-01 08:00 A (+16d) | 2006-10-16 10:00 → 2006-11-01 17:00 A (+16d) | 0.25d → 1d | 0% → 100% | 0d → none | 35 → 32 | baseline start none → 2006-11-01 08:00; baseline finish none → 2006-11-01 17:00 |
| 34 | PR 170 | 2006-11-24 10:00 → 2006-10-24 08:00 A (-31d) | 2006-11-24 15:00 → 2006-10-24 17:00 A (-31d) | 0.5d → 1d | 0% → 100% | 0d → none | PR 14 (3) → 33 | was named PR 153; baseline start none → 2006-10-24 08:00; baseline finish none → 2006-10-24 17:00 |
| 35 | PR 18 | 2006-10-13 13:00 → 2006-10-26 13:00 A (+13d) | 2006-10-13 17:00 → 2006-10-27 12:00 A (+14d) | 0.5d → 1d | 0% → 100% | 0d → none | 29 → 34 | baseline start none → 2006-10-26 13:00; baseline finish none → 2006-10-27 12:00 |
| 36 | PR 241 | 2006-09-19 08:00 A | 2006-09-19 12:00 → 2006-10-27 17:00 (+38d) | 0.5d → 2.5d | 0% → 80% | 48.25d → 0d | none → 35 | resources Gustavo → Gustavo [10%]; baseline start none → 2006-09-19 08:00; baseline finish none → 2006-10-27 17:00 |
| 37 | PR 261 | 2006-11-03 10:00 → 2006-10-30 08:00 (-4d) | 2006-11-03 15:00 → 2006-10-30 17:00 (-4d) | 0.5d → 1d |  |  | PR 15 → 36 | baseline start none → 2006-10-30 08:00; baseline finish none → 2006-10-30 17:00 |
| 38 | PR 3 | 2006-10-16 10:00 → 2006-10-31 08:00 (+15d) | 2006-10-30 10:00 → 2006-11-06 17:00 (+7d) | 10d → 5d |  |  | 33 → 37 | constraint none → start no earlier than 2006-09-29 08:00; baseline start none → 2006-10-31 08:00; baseline finish none → 2006-11-06 17:00 |
| 39 | PR 106 | 2006-10-31 10:00 → 2006-11-07 08:00 (+7d) | 2006-10-31 15:00 → 2006-11-07 12:00 (+7d) |  |  |  | PR 62 → 38 | baseline start none → 2006-11-07 08:00; baseline finish none → 2006-11-07 12:00 |
| 40 | PR 90 | 2006-11-01 15:00 → 2006-11-07 13:00 (+6d) | 2006-11-02 10:00 → 2006-11-07 17:00 (+5d) |  |  |  | 41 → 39 | baseline start none → 2006-11-07 13:00; baseline finish none → 2006-11-07 17:00 |
| 41 | PR 98 | 2006-10-31 15:00 → 2006-11-08 08:00 (+8d) | 2006-11-01 15:00 → 2006-11-08 17:00 (+7d) |  |  |  | 39 → 40 | baseline start none → 2006-11-08 08:00; baseline finish none → 2006-11-08 17:00 |
| 42 | PR 8 | 2006-11-24 15:00 → 2006-11-09 08:00 (-15d) | 2006-11-27 15:00 → 2006-11-09 17:00 (-18d) |  |  |  | 34 → 41 | baseline start none → 2006-11-09 08:00; baseline finish none → 2006-11-09 17:00 |
| 43 | Ajustes recomendados | 2006-11-28 15:00 → 2006-11-10 08:00 (-18d) | 2006-11-30 15:00 → 2006-11-16 17:00 (-14d) | 2d → 5d |  |  | PR 175 → 2 | baseline start none → 2006-11-10 08:00; baseline finish none → 2006-11-16 17:00 |
| 44 | **Gerencia de Proyecto** |  | 2006-11-30 12:00 → 2006-11-13 17:00 (-17d) | 57.5d → 45d |  | 0.25d → 3d |  | baseline start none → 2006-09-11 08:00; baseline finish none → 2006-11-13 17:00 |
| 45 | Planificación |  |  |  |  | 41.75d → 30.5d |  | baseline start none → 2006-09-12 08:00; baseline finish none → 2006-10-02 17:00 |
| 46 | **Control y Seguimiento** |  | 2006-11-30 10:00 → 2006-10-30 12:00 (-31d) | 57.25d → 34.5d |  | 0.5d → 13.5d |  | baseline start none → 2006-09-11 08:00; baseline finish none → 2006-10-30 12:00 |
| 47 | 11-09 |  | 2006-09-11 10:00 → 2006-09-11 12:00 | 0.25d → 0.5d |  | 57.5d → 46d |  | resources Gustavo [25%]; Kathy [25%]; Listbeth [25%]; Beta [25%] → Gustavo [25%]; Kathy [25%]; Listbeth [25%]; baseline start none → 2006-09-11 08:00; baseline finish none → 2006-09-11 12:00 |
| 48 | 18-09 | 2006-10-05 08:00 → 2006-09-18 08:00 (-17d) | 2006-10-05 10:00 → 2006-09-18 12:00 (-17d) | 0.25d → 0.5d |  | 39.5d → 41d |  | was named 05-10; constraint start no earlier than 2006-10-05 08:00 → start no earlier than 2006-09-18 08:00; resources Gustavo [25%]; Kathy [25%]; Listbeth [25%]; Beta [25%] → Gustavo [25%]; Kathy [25%]; Listbeth [25%]; baseline start none → 2006-09-18 08:00; baseline finish none → 2006-09-18 12:00 |
| 49 | 25-09 | 2006-10-11 08:00 → 2006-09-25 08:00 (-16d) | 2006-10-11 10:00 → 2006-09-25 12:00 (-16d) | 0.25d → 0.5d |  | 35.5d → 36d |  | was named 11-10; constraint start no earlier than 2006-10-11 08:00 → start no earlier than 2006-09-25 08:00; resources Gustavo [25%]; Kathy [25%]; Listbeth [25%]; Beta [25%] → Gustavo [25%]; Kathy [25%]; Listbeth [25%]; baseline start none → 2006-09-25 08:00; baseline finish none → 2006-09-25 12:00 |
| 50 | 02-10 | 2006-10-19 08:00 → 2006-10-02 08:00 (-17d) | 2006-10-19 10:00 → 2006-10-02 12:00 (-17d) | 0.25d → 0.5d |  | 30.5d → 31d |  | was named 19-10; constraint start no earlier than 2006-10-19 08:00 → start no earlier than 2006-10-02 08:00; resources Gustavo [25%]; Kathy [25%]; Listbeth [25%]; Beta [25%] → Gustavo [25%]; Kathy [25%]; Listbeth [25%]; baseline start none → 2006-10-02 08:00; baseline finish none → 2006-10-02 12:00 |
| 51 | 09-10 | 2006-10-26 08:00 → 2006-10-09 08:00 (-17d) | 2006-10-26 10:00 → 2006-10-09 12:00 (-17d) | 0.25d → 0.5d |  | 25.5d → 26d |  | was named 26-10; constraint start no earlier than 2006-10-26 08:00 → start no earlier than 2006-10-09 08:00; resources Gustavo [25%]; Kathy [25%]; Listbeth [25%]; Beta [25%] → Gustavo [25%]; Kathy [25%]; Listbeth [25%]; baseline start none → 2006-10-09 08:00; baseline finish none → 2006-10-09 12:00 |
| 52 | 16-10 | 2006-11-02 08:00 → 2006-10-16 08:00 (-17d) | 2006-11-02 10:00 → 2006-10-16 12:00 (-17d) | 0.25d → 0.5d |  | 20.5d → 22d |  | was named 02-11; constraint start no earlier than 2006-11-02 08:00 → start no earlier than 2006-10-16 08:00; resources Gustavo [25%]; Kathy [25%]; Listbeth [25%]; Beta [25%] → Gustavo [25%]; Kathy [25%]; Listbeth [25%]; baseline start none → 2006-10-16 08:00; baseline finish none → 2006-10-16 12:00 |
| 53 | 23-10 | 2006-11-09 08:00 → 2006-10-23 08:00 (-17d) | 2006-11-09 10:00 → 2006-10-23 12:00 (-17d) | 0.25d → 0.5d |  | 15.5d → 17d |  | was named 09-11; constraint start no earlier than 2006-11-09 08:00 → start no earlier than 2006-10-23 08:00; resources Gustavo [25%]; Kathy [25%]; Listbeth [25%]; Beta [25%] → Gustavo [25%]; Kathy [25%]; Listbeth [25%]; baseline start none → 2006-10-23 08:00; baseline finish none → 2006-10-23 12:00 |
| 55 | Cierre | 2006-11-30 08:00 → 2006-11-13 08:00 (-17d) | 2006-11-30 12:00 → 2006-11-13 17:00 (-17d) | 0.5d → 1d |  | 0.25d → 1.5d |  | constraint start no earlier than 2006-11-30 08:00 → start no earlier than 2006-11-13 08:00; resources Gustavo; Kathy; Listbeth; Beta → Gustavo; Kathy; Listbeth; baseline start none → 2006-11-13 08:00; baseline finish none → 2006-11-13 17:00 |

## Version 3 (saved 2006-10-31, file 20061031-1162322949.mpp)

Last finish 2006-11-16 → 2006-11-13 (-3d). Complete tasks 33 → 32.

Removed: 37 PR 261; 39 PR 106; 40 PR 90; 41 PR 98

Changed:

| ID | Task | Start | Finish | Duration | Complete | Total float | Predecessors |
| --- | --- | --- | --- | --- | --- | --- | --- |
| 1 | **Foto XS - PR´s** |  | 2006-11-16 17:00 → 2006-11-13 17:00 (-3d) | 52d → 49d | 47% → 50% |  |  |
| 2 | **Configuración y Desarrollo** |  | 2006-11-09 17:00 → 2006-11-06 17:00 (-3d) | 47d → 44d | 76% → 83% |  |  |
| 30 | PR 93 |  | 2006-10-25 17:00 A → 2006-10-25 17:00 |  | 100% → 50% | none → 8d |  |
| 35 | PR 18 |  | 2006-10-27 12:00 A → 2006-10-27 12:00 |  | 100% → 80% | none → 6.5d |  |
| 36 | PR 241 |  | 2006-10-27 17:00 A |  | 80% → 100% | 0d → none |  |
| 37 | PR 3 | 2006-10-31 08:00 → 2006-10-30 08:00 A (-1d) | 2006-11-06 17:00 → 2006-11-03 17:00 (-3d) |  | 0% → 10% |  | PR 261 → 36 |
| 38 | PR 8 | 2006-11-09 08:00 → 2006-11-06 08:00 (-3d) | 2006-11-09 17:00 → 2006-11-06 17:00 (-3d) |  |  |  | PR 98 → 37 |
| 39 | Ajustes recomendados | 2006-11-10 08:00 → 2006-11-07 08:00 (-3d) | 2006-11-16 17:00 → 2006-11-13 17:00 (-3d) |  |  |  |  |

## Version 4 (saved 2006-11-01, file 20061101-1162395082.mpp)

Last finish stays 2006-11-13. Complete tasks 32 → 33.

Removed: 38 PR 8

Changed:

| ID | Task | Start | Finish | Duration | Complete | Total float | Predecessors |
| --- | --- | --- | --- | --- | --- | --- | --- |
| 1 | **Foto XS - PR´s** |  |  |  | 50% → 51% |  |  |
| 2 | **Configuración y Desarrollo** |  | 2006-11-06 17:00 → 2006-11-03 17:00 (-3d) | 44d → 43d | 83% → 87% | 0d → 1d |  |
| 30 | PR 185 |  |  |  |  |  | 36 → 29 |
| 34 | PR 18 |  | 2006-10-27 12:00 A |  | 80% → 100% | 6.5d → none |  |
| 36 | PR 93 |  | 2006-10-25 17:00 → 2006-10-30 12:00 (+5d) |  |  | 8d → 1.25d | 29 → 35 |
| 37 | PR 3 |  |  |  | 10% → 15% | 0d → 1d | 35 → 36, 35 |
| 38 | Ajustes recomendados | 2006-11-07 08:00 → 2006-11-06 08:00 (-1d) | 2006-11-13 17:00 → 2006-11-10 17:00 (-3d) |  |  | 0d → 1d |  |
