# Planning Cines Unidos baseline

How a schedule from MS Project changed from version to version. A marks actual dates.

## Version 1 (saved 2007-05-17, file YYY20090209-8026096.mpp)

| ID | WBS | Task | Duration | Start | Finish | Predecessors | Total float | Constraint |
| --- | --- | --- | --- | --- | --- | --- | --- | --- |
| 1 | 1 | **Cines Unidos** | 205.5d | 2007-05-03 | 2008-02-22 |  | 0d |  |
| 2 |  | Reunión de Arranque (Kickoff) | 0.25d | 2007-05-03 | 2007-05-03 |  | 205.12d | start no earlier than 2007-05-03 |
| 3 | 1.2 | **Etapa I - Preparandonos para la Independencia** | 101.1d | 2007-05-04 | 2007-09-26 |  | 98.89d |  |
| 4 | 1.2.1 | **Fase I - Levantamiento de Información** | 30d | 2007-05-04 | 2007-06-15 |  | 174.38d |  |
| 5 |  | Levantamiento Info (Visita al Cine) | 0.5d | 2007-05-04 | 2007-05-04 |  | 203.88d | start no earlier than 2007-05-04 |
| 6 |  | Inducción Cines Unidos | 2d | 2007-05-09 | 2007-05-11 |  | 199.38d | start no earlier than 2007-05-09 |
| 7 |  | Presentación N2C y CRM | 0.38d | 2007-05-09 | 2007-05-09 |  | 201d | start no earlier than 2007-05-09 |
| 8 | 1.2.1.4 | **Modelo de Procesos** | 7.5d | 2007-05-14 | 2007-05-23 |  | 190.88d |  |
| 9 |  | Preparación para Mesas de Trabajo | 0.25d | 2007-05-14 | 2007-05-14 |  | 198.12d | start no earlier than 2007-05-14 |
| 10 |  | Mesa de Trabajo # 1 | 0.5d | 2007-05-15 | 2007-05-15 |  | 196.88d | start no earlier than 2007-05-15 |
| 11 |  | Mesa de Trabajo # 2 | 0.5d | 2007-05-17 | 2007-05-17 |  | 194.88d | start no earlier than 2007-05-17 |
| 12 |  | Mesa de Trabajo # 3 | 0.5d | 2007-05-23 | 2007-05-23 |  | 190.88d | start no earlier than 2007-05-23 |
| 13 |  | Documentación Modelo de Procesos | 4d | 2007-05-17 | 2007-05-23 |  | 191.38d | start no earlier than 2007-05-17 |
| 14 | 1.2.1.5 | **Modelo de Datos** | 9.88d | 2007-05-22 | 2007-06-04 |  | 182.5d |  |
| 15 |  | Análisis Modelo de Datos Actual | 0.25d | 2007-05-22 | 2007-05-22 |  | 192.12d | start no earlier than 2007-05-22 |
| 16 |  | Elaboración Modelo de Datos Preliminar | 1d | 2007-05-24 | 2007-05-25 |  | 189.38d | start no earlier than 2007-05-24 |
| 17 |  | Mesa de Trabajo - Kernel | 0.5d | 2007-05-30 | 2007-05-30 |  | 185.88d | start no earlier than 2007-05-30 |
| 18 |  | Mesa de Trabajo # 4 (Sist CU - GWT) | 0.5d | 2007-05-31 | 2007-05-31 |  | 181.88d | start no earlier than 2007-05-31 |
| 19 |  | Ajustes al Modelo | 2d | 2007-06-01 | 2007-06-04 |  | 182.5d | finish no earlier than 2007-06-04 |
| 20 | 1.2.1.6 | **Configuración Ambiente de Desarrollo** | 10d | 2007-05-29 | 2007-06-12 |  | 177.38d |  |
| 21 |  | Análisis Req. Adiestramiento configuración e instalación de Vista y MegaSoft | 2d | 2007-05-29 | 2007-05-31 |  | 185.38d | start no earlier than 2007-05-29 |
| 22 |  | Instalación y configuración de ambiente a imágen y semejanza de ambiente de producción de Cines Unidos | 6d | 2007-06-04 | 2007-06-12 |  | 177.38d | start no earlier than 2007-06-04 |
| 23 |  | Configuración de VPN para acceso remoto | 5.33d | 2007-06-04 | 2007-06-11 |  | 178.04d | start no earlier than 2007-06-04 |
| 24 | 1.2.1.7 | **Infraestructura a Futuro** | 20d | 2007-05-14 | 2007-06-11 |  | 178.38d |  |
| 25 |  | Investigación de requerimientos de infraestructura | 15d | 2007-05-14 | 2007-06-04 |  | 178.38d | start no earlier than 2007-05-14 |
| 26 |  | Elaborar informe | 5d | 2007-06-04 | 2007-06-11 | 25 | 178.38d |  |
| 27 | 1.2.1.8 | **Informe de Especificación de Requerimientos** | 10.5d | 2007-05-31 | 2007-06-15 |  | 174.38d |  |
| 28 |  | Elaboración del Informe de Especificación de Requerimientos | 3d | 2007-05-31 | 2007-06-05 | 18 | 181.88d |  |
| 29 |  | Entrega al Equipo de Proyecto CU para su revisión | 0d | 2007-06-05 | 2007-06-05 | 28 | 181.88d | start no earlier than 2006-12-01 |
| 30 |  | Revisión por parte del Equipo de Proyecto CU | 2d | 2007-06-06 | 2007-06-08 |  | 173.38d | start no earlier than 2007-06-06 |
| 31 |  | Ajustes al Informe Especificación de Requerimientos | 2d | 2007-06-11 | 2007-06-12 | 30 | 172.5d | finish no earlier than 2007-06-12 |
| 32 |  | Entrega de Especificación de Req. para aprobación | 0d | 2007-06-12 | 2007-06-12 | 31 | 172.5d | start no earlier than 2006-12-07 |
| 33 |  | Aprobación del Informe Especificación de Requerimientos | 0d | 2007-06-15 | 2007-06-15 | 32 | 170.38d | start no earlier than 2007-06-15 |
| 34 |  | Informe Especificación de Requerimientos Aprobado | 0d | 2007-06-15 | 2007-06-15 | 33 | 174.38d |  |
| 35 |  | Modelo de Procesos Definido | 0d | 2007-06-15 | 2007-06-15 | 33 | 174.38d |  |
| 36 |  | Modelo de Datos Definido | 0d | 2007-06-15 | 2007-06-15 | 33 | 170.38d |  |
| 37 |  | Informe Infraestructura y Crecimiento Futuro | 0d | 2007-06-15 | 2007-06-15 | 33 | 174.38d |  |
| 38 | 1.2.6 | **Fase II - Conformación de las bases** | 38.5d | 2007-06-06 | 2007-08-01 |  | 124.88d |  |
| 39 | 1.2.6.1 | **Directorio de Clientes y CRM** | 13d | 2007-06-06 | 2007-06-25 |  | 124.88d |  |
| 40 |  | Análisis de Base de Datos de Clientes y Transacciones del proveedor actual (BD) | 0.5d | 2007-06-06 | 2007-06-06 |  | 180.88d | start no earlier than 2007-06-06 |
| 41 |  | Equivalencia entre la base de datos del Proveedor Actual vs. lo levantado | 0.5d | 2007-06-07 | 2007-06-07 |  | 169.88d | start no earlier than 2007-06-07 |
| 42 |  | Crear en N2C la nueva estructura de la B.D de Clientes | 1d | 2007-06-07 | 2007-06-08 | 41 | 2.88d |  |
| 43 |  | Configuración Directorio de Clientes | 4d | 2007-06-08 | 2007-06-14 | 42 | 169.88d |  |
| 44 |  | Carga inicial de datos de Clientes y Transacciones en N2C | 3d | 2007-06-14 | 2007-06-19 | 43 | 169.88d |  |
| 45 |  | Implementar mecanismo de carga diaria de datos provenientes del Proveedor Actual a Cines Unidos | 1d | 2007-06-19 | 2007-06-20 | 44 | 169.88d |  |
| 46 |  | Implementar facilidad de monitoreo quincenal de los datos para su depuración | 1d | 2007-06-20 | 2007-06-21 | 45 | 169.88d |  |
| 47 |  | Envio de correos masivos con políticas de colas y administración de mensajes devueltos | 4d | 2007-06-15 | 2007-06-21 | 36 | 170.38d |  |
| 48 | 1.2.6.1.9 | **Reportes de Clientes** | 7d | 2007-06-14 | 2007-06-25 |  | 118.88d |  |
| 49 |  | Implementación de 10 reportes básicos | 4d | 2007-06-14 | 2007-06-20 |  | 10.88d | start no earlier than 2007-06-14 |
| 50 |  | Implementación de 3 reportes estadísticos | 3d | 2007-06-20 | 2007-06-25 | 49 | 118.88d |  |
| 51 |  | CRM | 16d | 2007-06-25 | 2007-07-18 | 50 | 118.88d |  |
| 52 | 1.2.6.3 | **Implantación** | 9.5d | 2007-07-18 | 2007-08-01 |  | 118.88d |  |
| 53 |  | Pruebas internas | 2d | 2007-07-18 | 2007-07-20 | 51 | 148.38d |  |
| 54 |  | Ajustes recomendados | 2d | 2007-07-20 | 2007-07-25 | 53 | 148.38d |  |
| 55 |  | Documentación | 5d | 2007-07-18 | 2007-07-26 | 51 | 118.88d |  |
| 56 |  | Adiestramiento | 1.5d | 2007-07-26 | 2007-07-27 | 55 | 118.88d |  |
| 57 |  | Pruebas de Certificación | 3d | 2007-07-27 | 2007-08-01 | 56 | 118.88d |  |
| 58 |  | Directorios de Clientes implantado | 0d | 2007-08-01 | 2007-08-01 | 57 | 142.88d |  |
| 59 |  | Reportes y Estadísticas de Clientes implantado | 0d | 2007-08-01 | 2007-08-01 | 57 | 142.88d |  |
| 60 |  | CRM implantado | 0d | 2007-08-01 | 2007-08-01 | 57 | 142.88d |  |
| 61 |  | Adiestramiento Asterisk | 3d | 2007-06-18 | 2007-06-21 |  | 170.38d | start no earlier than 2007-06-18 |
| 62 | 1.2.11 | **Fase III - Integración** | 62.1d | 2007-06-21 | 2007-09-19 |  | 64.89d |  |
| 63 |  | Vista | 40d | 2007-06-21 | 2007-08-20 |  | 113.38d | start no earlier than 2007-06-21 |
| 64 |  | MegaSoft | 24d | 2007-08-01 | 2007-09-04 | 57 | 118.88d |  |
| 65 |  | Pagina Web | 15.5d | 2007-08-01 | 2007-09-11 |  | 114.5d | start no earlier than 2007-08-01 |
| 66 | 1.2.11.4 | **Implantación** | 22.1d | 2007-08-20 | 2007-09-19 |  | 24.89d |  |
| 67 |  | Pruebas internas | 15d | 2007-08-20 | 2007-09-10 | 63 | 113.38d |  |
| 68 |  | Ajustes recomendados | 2d | 2007-09-10 | 2007-09-12 | 67 | 113.38d |  |
| 69 |  | Documentación | 15d | 2007-08-20 | 2007-09-10 | 63 | 115.38d |  |
| 70 |  | Adiestramiento | 1.1d | 2007-09-13 | 2007-09-14 |  | 6.89d | start no earlier than 2007-09-13 |

| ID | WBS | Task | Duration | Start | Finish | Predecessors | Total float | Constraint |
| --- | --- | --- | --- | --- | --- | --- | --- | --- |
| 71 |  | Pruebas de Certificación | 3d | 2007-09-14 | 2007-09-19 | 70 | 108.28d |  |
| 72 |  | N2C y Vista Integrados | 0d | 2007-09-19 | 2007-09-19 | 71 | 108.28d |  |
| 73 |  | N2C y Merchant integrados | 0d | 2007-09-19 | 2007-09-19 | 71 | 108.28d |  |
| 74 |  | N2C y Página web integrados | 0d | 2007-09-19 | 2007-09-19 | 71 | 108.28d |  |
| 75 | 1.2.15 | **Fase IV - Independencia** | 8d | 2007-09-14 | 2007-09-26 |  | 6.89d |  |
| 76 |  | Pruebas Independencia | 5d | 2007-09-14 | 2007-09-21 | 70 | 6.89d |  |
| 77 |  | Independizarse del proveedor actual | 3d | 2007-09-21 | 2007-09-26 | 76 | 6.89d |  |
| 78 |  | Cines Unidos independizado de Proveedor Actual | 0d | 2007-09-26 | 2007-09-26 | 77 | 2.28d |  |
| 79 | 1.3 | **Etapa II - Hacia al e_Business** | 56.38d | 2007-09-26 | 2007-12-14 |  | 6.89d |  |
| 80 |  | Cartelera Cinematográfica | 12d | 2007-09-26 | 2007-10-15 | 78 | 67.28d |  |
| 81 |  | Integración Call Center | 30d | 2007-09-26 | 2007-11-08 | 78 | 6.89d |  |
| 82 |  | Integración con Asterisk (**) | 13d | 2007-11-08 | 2007-11-27 | 81 | 60.28d |  |
| 83 |  | Integración Tienda Cines Unidos | 24d | 2007-10-15 | 2007-11-16 | 80 | 67.28d |  |
| 84 |  | Integración Taquilla | 15.38d | 2007-11-08 | 2007-11-29 | 81 | 6.89d |  |
| 85 |  | Pruebas internas | 2.5d | 2007-11-29 | 2007-12-04 | 84 | 6.89d |  |
| 86 |  | Documentación | 2.5d | 2007-12-04 | 2007-12-06 | 85 | 6.89d |  |
| 87 |  | Adiestramiento | 2d | 2007-12-06 | 2007-12-10 | 86 | 6.89d |  |
| 88 |  | Pruebas de Certificación | 4d | 2007-12-10 | 2007-12-14 | 87 | 6.89d |  |
| 89 |  | Cartelera Cinematográfica implantada | 0d | 2007-12-14 | 2007-12-14 | 88 | 46.89d |  |
| 90 |  | Integración Call Center implantado | 0d | 2007-12-14 | 2007-12-14 | 88 | 46.89d |  |
| 91 |  | Integración Tienda Cines Unidos implantado | 0d | 2007-12-14 | 2007-12-14 | 88 | 6.89d |  |
| 92 | 1.4 | **Etapa III - Inteligencia de Negocio** | 40d | 2007-12-14 | 2008-02-13 |  | 6.89d |  |
| 93 |  | Integración con InfoWorks | 40d | 2007-12-14 | 2008-02-13 | 91 | 6.89d | start no earlier than 2007-11-01 |
| 94 |  | Evaluación tecnológica de Pentaho | 10d | 2007-12-14 | 2008-01-02 | 91 | 36.89d | start no earlier than 2007-11-01 |
| 95 |  | Gerencia de Proyectos | 205d | 2007-05-03 | 2008-02-21 |  | 0d | finish no earlier than 2008-02-21 |
| 96 |  | Cierre | 0.5d | 2008-02-22 | 2008-02-22 | 95 | 0d |  |

## Version 2 (saved 2008-07-23, file 20081010-1223668245.mpp)

Last finish stays 2008-02-22. Complete tasks 0 → 51.

Changed:

| ID | Task | Start | Finish | Duration | Complete | Total float |
| --- | --- | --- | --- | --- | --- | --- |
| 1 | **Cines Unidos** | 2007-05-03 A |  | 205.5d → 205.38d | 0% → 67% |  |
| 2 | Reunión de Arranque (Kickoff) | 2007-05-03 A | 2007-05-03 A |  | 0% → 100% | 205.12d → none |
| 3 | **Etapa I - Preparandonos para la Independencia** | 2007-05-04 A |  |  | 0% → 90% | 98.89d → 103.28d |
| 4 | **Fase I - Levantamiento de Información** | 2007-05-04 A | 2007-06-15 A |  | 0% → 100% | 174.38d → none |
| 5 | Levantamiento Info (Visita al Cine) | 2007-05-04 A | 2007-05-04 A |  | 0% → 100% | 203.88d → none |
| 6 | Inducción Cines Unidos | 2007-05-09 A | 2007-05-11 A |  | 0% → 100% | 199.38d → none |
| 7 | Presentación N2C y CRM | 2007-05-09 A | 2007-05-09 A |  | 0% → 100% | 201d → none |
| 8 | **Modelo de Procesos** | 2007-05-14 A | 2007-05-23 A |  | 0% → 100% | 190.88d → none |
| 9 | Preparación para Mesas de Trabajo | 2007-05-14 A | 2007-05-14 A |  | 0% → 100% | 198.12d → none |
| 10 | Mesa de Trabajo # 1 | 2007-05-15 A | 2007-05-15 A |  | 0% → 100% | 196.88d → none |
| 11 | Mesa de Trabajo # 2 | 2007-05-17 A | 2007-05-17 A |  | 0% → 100% | 194.88d → none |
| 12 | Mesa de Trabajo # 3 | 2007-05-23 A | 2007-05-23 A |  | 0% → 100% | 190.88d → none |
| 13 | Documentación Modelo de Procesos | 2007-05-17 A | 2007-05-23 → 2007-05-22 A (-1d) |  | 0% → 100% | 191.38d → none |
| 14 | **Modelo de Datos** | 2007-05-22 A | 2007-06-04 A | 9.88d → 10d | 0% → 100% | 182.5d → none |
| 15 | Análisis Modelo de Datos Actual | 2007-05-22 A | 2007-05-22 A |  | 0% → 100% | 192.12d → none |
| 16 | Elaboración Modelo de Datos Preliminar | 2007-05-24 A | 2007-05-25 A |  | 0% → 100% | 189.38d → none |
| 17 | Mesa de Trabajo - Kernel | 2007-05-30 A | 2007-05-30 A |  | 0% → 100% | 185.88d → none |
| 18 | Mesa de Trabajo # 4 (Sist CU - GWT) | 2007-05-31 A | 2007-05-31 A |  | 0% → 100% | 181.88d → none |
| 19 | Ajustes al Modelo | 2007-06-01 A | 2007-06-04 A |  | 0% → 100% | 182.5d → none |
| 20 | **Configuración Ambiente de Desarrollo** | 2007-05-29 A | 2007-06-12 A |  | 0% → 100% | 177.38d → none |
| 21 | Análisis Req. Adiestramiento configuración e instalación de Vista y MegaSoft | 2007-05-29 A | 2007-05-31 A |  | 0% → 100% | 185.38d → none |
| 22 | Instalación y configuración de ambiente a imágen y semejanza de ambiente de producción de Cines Unidos | 2007-06-04 A | 2007-06-12 A |  | 0% → 100% | 177.38d → none |
| 23 | Configuración de VPN para acceso remoto | 2007-06-04 A | 2007-06-11 A |  | 0% → 100% | 178.04d → none |
| 24 | **Infraestructura a Futuro** | 2007-05-14 A | 2007-06-11 → 2007-06-08 A (-3d) |  | 0% → 100% | 178.38d → none |
| 25 | Investigación de requerimientos de infraestructura | 2007-05-14 A | 2007-06-04 → 2007-06-01 A (-3d) |  | 0% → 100% | 178.38d → none |
| 26 | Elaborar informe | 2007-06-04 A | 2007-06-11 → 2007-06-08 A (-3d) |  | 0% → 100% | 178.38d → none |
| 27 | **Informe de Especificación de Requerimientos** | 2007-05-31 A | 2007-06-15 A |  | 0% → 100% | 174.38d → none |
| 28 | Elaboración del Informe de Especificación de Requerimientos | 2007-05-31 A | 2007-06-05 A |  | 0% → 100% | 181.88d → none |
| 29 | Entrega al Equipo de Proyecto CU para su revisión | 2007-06-05 A | 2007-06-05 A |  | 0% → 100% | 181.88d → none |
| 30 | Revisión por parte del Equipo de Proyecto CU | 2007-06-06 A | 2007-06-08 A |  | 0% → 100% | 173.38d → none |
| 31 | Ajustes al Informe Especificación de Requerimientos | 2007-06-11 A | 2007-06-12 A |  | 0% → 100% | 172.5d → none |
| 32 | Entrega de Especificación de Req. para aprobación | 2007-06-12 A | 2007-06-12 A |  | 0% → 100% | 172.5d → none |
| 33 | Aprobación del Informe Especificación de Requerimientos | 2007-06-15 A | 2007-06-15 A |  | 0% → 100% | 170.38d → none |
| 34 | Informe Especificación de Requerimientos Aprobado | 2007-06-15 A | 2007-06-15 A |  | 0% → 100% | 174.38d → none |
| 35 | Modelo de Procesos Definido | 2007-06-15 A | 2007-06-15 A |  | 0% → 100% | 174.38d → none |
| 36 | Modelo de Datos Definido | 2007-06-15 A | 2007-06-15 A |  | 0% → 100% | 170.38d → none |
| 37 | Informe Infraestructura y Crecimiento Futuro | 2007-06-15 A | 2007-06-15 A |  | 0% → 100% | 174.38d → none |
| 38 | **Fase II - Conformación de las bases** | 2007-06-06 A | 2007-08-01 A |  | 0% → 100% | 124.88d → none |
| 39 | **Directorio de Clientes y CRM** | 2007-06-06 A | 2007-06-25 → 2007-06-22 A (-3d) |  | 0% → 100% | 124.88d → none |
| 40 | Análisis de Base de Datos de Clientes y Transacciones del proveedor actual (BD) | 2007-06-06 A | 2007-06-06 A |  | 0% → 100% | 180.88d → none |
| 41 | Equivalencia entre la base de datos del Proveedor Actual vs. lo levantado | 2007-06-07 A | 2007-06-07 A |  | 0% → 100% | 169.88d → none |
| 42 | Crear en N2C la nueva estructura de la B.D de Clientes | 2007-06-07 A | 2007-06-08 A |  | 0% → 100% | 2.88d → none |
| 43 | Configuración Directorio de Clientes | 2007-06-08 A | 2007-06-14 A |  | 0% → 100% | 169.88d → none |
| 44 | Carga inicial de datos de Clientes y Transacciones en N2C | 2007-06-14 A | 2007-06-19 A |  | 0% → 100% | 169.88d → none |
| 45 | Implementar mecanismo de carga diaria de datos provenientes del Proveedor Actual a Cines Unidos | 2007-06-19 A | 2007-06-20 A |  | 0% → 100% | 169.88d → none |
| 46 | Implementar facilidad de monitoreo quincenal de los datos para su depuración | 2007-06-20 A | 2007-06-21 A |  | 0% → 100% | 169.88d → none |
| 47 | Envio de correos masivos con políticas de colas y administración de mensajes devueltos | 2007-06-15 A | 2007-06-21 → 2007-06-20 A (-1d) |  | 0% → 100% | 170.38d → none |
| 48 | **Reportes de Clientes** | 2007-06-14 A | 2007-06-25 → 2007-06-22 A (-3d) |  | 0% → 100% | 118.88d → none |
| 49 | Implementación de 10 reportes básicos | 2007-06-14 A | 2007-06-20 → 2007-06-19 A (-1d) |  | 0% → 100% | 10.88d → none |
| 50 | Implementación de 3 reportes estadísticos | 2007-06-20 A | 2007-06-25 → 2007-06-22 A (-3d) |  | 0% → 100% | 118.88d → none |
| 51 | CRM | 2007-06-25 A | 2007-07-18 → 2007-07-17 A (-1d) |  | 0% → 100% | 118.88d → none |
| 52 | **Implantación** | 2007-07-18 A | 2007-08-01 A |  | 0% → 100% | 118.88d → none |
| 53 | Pruebas internas | 2007-07-18 A | 2007-07-20 → 2007-07-19 A (-1d) |  | 0% → 100% | 148.38d → none |
| 54 | Ajustes recomendados | 2007-07-20 A | 2007-07-25 → 2007-07-23 A (-2d) |  | 0% → 100% | 148.38d → none |
| 55 | Documentación | 2007-07-18 A | 2007-07-26 → 2007-07-25 A (-1d) |  | 0% → 100% | 118.88d → none |
| 56 | Adiestramiento | 2007-07-26 A | 2007-07-27 A |  | 0% → 100% | 118.88d → none |
| 57 | Pruebas de Certificación | 2007-07-27 A | 2007-08-01 A |  | 0% → 100% | 118.88d → none |
| 58 | Directorios de Clientes implantado | 2007-08-01 A | 2007-08-01 A |  | 0% → 100% | 142.88d → none |
| 59 | Reportes y Estadísticas de Clientes implantado | 2007-08-01 A | 2007-08-01 A |  | 0% → 100% | 142.88d → none |
| 60 | CRM implantado | 2007-08-01 A | 2007-08-01 A |  | 0% → 100% | 142.88d → none |
| 61 | Adiestramiento Asterisk | 2007-06-18 A | 2007-06-21 A |  | 0% → 100% | 170.38d → none |
| 62 | **Fase III - Integración** | 2007-06-21 A |  |  | 0% → 86% | 64.89d → 108.28d |
| 63 | Vista | 2007-06-21 A | 2007-08-20 → 2007-08-17 A (-3d) |  | 0% → 100% | 113.38d → none |
| 64 | MegaSoft | 2007-08-01 A | 2007-09-04 A |  | 0% → 100% | 118.88d → none |
| 65 | Pagina Web | 2007-08-01 A | 2007-09-11 → 2007-09-10 (-1d) | 15.5d → 15d | 0% → 90% |  |
| 66 | **Implantación** | 2007-08-20 A |  |  | 0% → 58% | 24.89d → 108.28d |
| 67 | Pruebas internas | 2007-08-20 A | 2007-09-10 → 2007-09-07 (-3d) |  | 0% → 80% | 113.38d → 114.88d |
| 68 | Ajustes recomendados | 2007-09-10 A | 2007-09-12 → 2007-09-11 (-1d) |  | 0% → 75% |  |
| 69 | Documentación | 2007-08-20 A | 2007-09-10 → 2007-09-07 (-3d) |  | 0% → 50% |  |
| 75 | **Fase IV - Independencia** | 2007-09-14 A |  |  | 0% → 31% | 6.89d → 20.63d |

| ID | Task | Start | Finish | Complete | Total float |
| --- | --- | --- | --- | --- | --- |
| 76 | Pruebas Independencia | 2007-09-14 A |  | 0% → 50% | 6.89d → 20.63d |
| 79 | **Etapa II - Hacia al e_Business** | 2007-09-26 A |  | 0% → 25% | 6.89d → 46.89d |
| 81 | Integración Call Center | 2007-09-26 A |  | 0% → 30% | 6.89d → 11.63d |
| 82 | Integración con Asterisk (**) | 2007-11-08 A |  | 0% → 60% |  |
| 84 | Integración Taquilla | 2007-11-08 A |  | 0% → 60% | 6.89d → 7.64d |
| 85 | Pruebas internas | 2007-11-29 A | 2007-12-04 → 2007-12-03 (-1d) | 0% → 25% | 6.89d → 7.02d |
| 86 | Documentación | 2007-12-04 → 2007-12-03 (-1d) |  |  |  |
| 92 | **Etapa III - Inteligencia de Negocio** | 2007-12-14 A |  | 0% → 4% |  |
| 94 | Evaluación tecnológica de Pentaho | 2007-12-14 A |  | 0% → 20% |  |
| 95 | Gerencia de Proyectos | 2007-05-03 A |  | 0% → 78% |  |
