# Nuevo Pendientes-Factibles

How a schedule from MS Project changed from version to version. A marks actual dates.

## Version 1 (saved 2008-08-20, file YYY20080820-6666914.mpp)

| ID | WBS | Task | Duration | Start | Finish | Predecessors | Complete | Total float | Constraint |
| --- | --- | --- | --- | --- | --- | --- | --- | --- | --- |
| 1 | 1 | **Cines Unidos** | 99.9d | 2008-06-10 A | 2008-10-28 |  | 44% | 0d |  |
| 2 | 1.1 | **Etapa I y II** | 82.76d | 2008-07-04 A | 2008-10-28 |  | 35% | 0d |  |
| 3 |  | Pase de BD a Pippin | 0.5d | 2008-08-11 A | 2008-08-11 A |  | 100% |  | start no earlier than 2008-08-11 |
| 4 | 1.1.2 | **Fase III - Integración** | 70.76d | 2008-07-04 A | 2008-10-10 |  | 43% | 0d |  |
| 5 |  | Integración Pagina Web (sin valores foráneos) | 20d | 2008-07-04 A | 2008-07-31 A |  | 100% |  | start no earlier than 2008-07-04 |
| 6 |  | Entrega de Data en mdb Tiendas | 1d | 2008-08-06 A | 2008-08-06 A |  | 100% |  | start no earlier than 2008-08-06 |
| 7 |  | Integración Tienda Cines Unidos | 8d | 2008-08-07 A | 2008-08-18 A | 6 | 100% |  |  |
| 8 |  | Ajuste con Listas de Valores en Integración Sitio Web | 1d | 2008-08-13 A | 2008-08-13 A | 7 | 100% |  |  |
| 9 |  | Modificación Formulario de Contacto para Sitio Web | 1d | 2008-08-21 | 2008-08-21 |  |  | 34.76d | start no earlier than 2008-08-21 |
| 10 |  | Pruebas de Certificación de Módulo de Contacto en Pippin | 1d | 2008-08-22 | 2008-08-22 | 9 |  | 34.76d |  |
| 11 |  | Entrega a GWT de lista de valores Ciudad, Estado y Cinemas de Sitio Web | 0d | 2008-08-22 | 2008-08-22 |  |  | 35.26d | start no earlier than 2008-08-22 |
| 12 |  | Ajuste de Integración Sitio Web con listas de valores reales | 0.5d | 2008-08-22 | 2008-08-22 | 11 |  | 35.26d |  |
| 13 |  | Preparación material para adiestramiento Módulo de Contacto | 0.5d | 2008-08-25 | 2008-08-25 |  |  | 34.26d | start no earlier than 2008-08-25 |
| 14 |  | Adiestramiento a personal Cines Unidos en Manejo de Contactos | 0.25d | 2008-08-27 | 2008-08-27 |  |  | 31.26d | start no earlier than 2008-08-27 |
| 15 |  | Limpieza de tablas en Pippin | 0.4d | 2008-08-27 | 2008-08-27 | 14 |  | 31.11d |  |
| 16 |  | CRM con Módulo de Contacto en Producción | 1d | 2008-08-27 | 2008-08-28 | 15 |  | 31.11d |  |
| 17 |  | Integración Transacciones Web | 8d | 2008-08-25 | 2008-09-03 |  |  | 0d | start no earlier than 2008-08-25 |
| 18 |  | Integración Vista | 7d | 2008-09-04 | 2008-09-12 | 17 |  | 0d |  |
| 19 |  | Integración CC Vista | 12d | 2008-09-15 | 2008-09-30 | 18 |  | 0d |  |
| 20 |  | Pruebas internas | 3.76d | 2008-10-01 | 2008-10-06 | 19 |  | 0d |  |
| 21 |  | Ajustes recomendados | 4d | 2008-10-06 | 2008-10-10 | 20 |  | 0d |  |
| 22 |  | Migración de Programas de Integración a Pippin (dir desarrollo) | 2d | 2008-10-10 | 2008-10-14 | 4 |  | 0d |  |
| 23 |  | Preparación Pruebas de Certificación | 3d | 2008-10-14 | 2008-10-17 | 22 |  | 0d |  |
| 24 |  | Apoyo en Pruebas de Certificación | 5d | 2008-10-17 | 2008-10-24 | 23 |  | 2d |  |
| 25 |  | Pruebas de Certificación por parte de Cines Unidos | 5d | 2008-10-17 | 2008-10-24 | 23 |  | 0d |  |
| 26 |  | Pase a Producción de Integraciones | 1d | 2008-10-24 | 2008-10-27 | 25 |  | 0d |  |
| 27 |  | CRM completo en Producción | 1d | 2008-10-27 | 2008-10-28 | 26 |  | 0d |  |
| 28 | 1.2 | **Etapa III - Inteligencia de Negocio** | 12.14d | 2008-06-10 A | 2008-06-26 A |  | 100% |  |  |
| 29 |  | Evaluación tecnológica de Pentaho | 11.14d | 2008-06-10 A | 2008-06-25 A |  | 100% |  | finish no earlier than 2008-06-25 |
| 30 |  | Informe comparativo entregado | 1d | 2008-06-26 A | 2008-06-26 A | 29 | 100% |  |  |
| 31 |  | Gerencia de Proyectos | 67.5d | 2008-07-04 A | 2008-10-27 |  | 45% | 0.76d | start no earlier than 2008-07-04 |

## Version 2 (saved 2008-09-18, file 20081010-1223668448.mpp)

Last finish stays 2008-10-28. Complete tasks 7 → 11.

Changed:

| ID | Task | Start | Finish | Complete | Total float |
| --- | --- | --- | --- | --- | --- |
| 1 | **Cines Unidos** |  |  | 44% → 56% |  |
| 2 | **Etapa I y II** |  |  | 35% → 38% |  |
| 4 | **Fase III - Integración** |  |  | 43% → 47% |  |
| 9 | Modificación Formulario de Contacto para Sitio Web | 2008-08-21 A | 2008-08-21 A | 0% → 100% | 34.76d → none |
| 10 | Pruebas de Certificación de Módulo de Contacto en Pippin | 2008-08-22 A | 2008-08-22 A | 0% → 100% | 34.76d → none |
| 11 | Entrega a GWT de lista de valores Ciudad, Estado y Cinemas de Sitio Web | 2008-08-22 A |  | 0% → 90% | 35.26d → 0d |
| 13 | Preparación material para adiestramiento Módulo de Contacto | 2008-08-25 A | 2008-08-25 A | 0% → 100% | 34.26d → none |
| 14 | Adiestramiento a personal Cines Unidos en Manejo de Contactos | 2008-08-27 A | 2008-08-27 A | 0% → 100% | 31.26d → none |
| 31 | Gerencia de Proyectos |  |  | 45% → 70% |  |
