# Proyect1

How a schedule from MS Project changed from version to version. A marks actual dates.

## Version 1 (saved 2005-12-13, file YYY20051213-3371438.mpp)

| ID | WBS | Task | Duration | Start | Finish | Predecessors | Complete | Total float | Constraint |
| --- | --- | --- | --- | --- | --- | --- | --- | --- | --- |
| 1 | 1 | **Proyecto "e-orchestra"** | 89d | 2005-11-28 A | 2006-03-30 |  | 9% | 0d |  |
| 2 | 1.1 | **Fase de Análisis** | 23d | 2005-11-28 A | 2005-12-28 |  | 24% | 66d |  |
| 3 | 1.1.1 | **Levantamiento de la información** | 23d | 2005-11-28 A | 2005-12-28 |  | 24% | 66d |  |
| 4 |  | Conocer la plataforma, herramientas computacionales y/o sistemas utilizados para los procesos internos. | 5d | 2005-11-28 A | 2005-12-02 A |  | 100% |  | finish no earlier than 2005-12-02 |
| 5 | 1.1.1.2 | **Entrevista por grupos responsables de las diferentes áreas de negocio de la empresa y de los subproyectos de e-orchestra** | 18d | 2005-12-05 A | 2005-12-28 | 4 | 13% | 66d |  |
| 6 |  | Estructurar Cuestionario de las Entrevistas | 2d | 2005-12-05 A | 2005-12-06 A |  | 100% |  |  |
| 7 |  | Estructurar un Calendario de Entrevistas | 0.5d | 2005-12-05 A | 2005-12-05 A |  | 100% |  |  |
| 8 |  | Determinar las necesidades del usuario para realizar su trabajo de manera óptima | 16d | 2005-12-07 A | 2005-12-28 | 7, 6 | 6% | 66d | finish no earlier than 2005-12-16 |
| 9 |  | Reconocer los procesos empresariales | 16d | 2005-12-07 A | 2005-12-28 | 7, 6 | 6% | 0d | finish no earlier than 2005-12-16 |
| 10 | 1.2 | **Fase de Diseño** | 26d | 2005-12-29 | 2006-02-02 | 9 |  | 0d |  |
| 11 |  | Diseñar el sistema a implementar aplicando la metodología de desarrollo propuesta para la gerencia de proyectos de informática lo cual permitirá optimizar el seguimiento y desarrollo de los mismos | 25d | 2005-12-29 | 2006-02-01 |  |  | 0d | finish no earlier than 2006-01-06 |
| 12 |  | Diseñar la estructura de los documentos que en línea mostrarán los procedimientos asociados con el sistema. | 5d | 2006-01-19 | 2006-01-25 | 11SS+15d |  | 5d |  |
| 13 |  | Entregable: Interfaz del sistema y diseño de la estructura de la documentación de procedimientos | 1d | 2006-02-02 | 2006-02-02 | 11, 12 |  | 0d | start no earlier than 2006-01-06 |
| 14 | 1.3 | **Fase de Desarrollo** | 40d | 2006-02-03 | 2006-03-30 | 13 |  | 0d |  |
| 15 |  | Elaboración de un documento en línea de procedimientos que permita optimizar el desarrollo y seguimiento de proyectos de informática, a la empresa GWT | 39d | 2006-02-03 | 2006-03-29 |  |  | 0d | finish no earlier than 2006-03-02 |
| 16 |  | Entregable: Sistema, herramienta de software, que de soporte a la metodología de desarrollo propuesta | 1d | 2006-03-30 | 2006-03-30 | 15 |  | 0d |  |

## Version 2 (saved 2006-01-10, file YYY20060110-6034523.mpp)

Last finish 2006-03-30 → 2006-03-03 (-27d). Complete tasks 3 → 6.

Added:

| ID | Task | Duration | Start | Finish | Predecessors | Constraint |
| --- | --- | --- | --- | --- | --- | --- |
| 9 | Entrevistar a los responsables de áreas de negocio de GWT | 6d? | 2005-12-07 A | 2005-12-14 A |  | start no earlier than 2005-12-07 |
| 10 | Analizar resultados de encuestas | 2d? | 2005-12-15 A | 2005-12-16 A | 9 | start no earlier than 2005-12-15 |
| 12 | Documentar procesos en un primer nivel (nivel 0) sin interconexión | 8d? | 2005-12-19 A | 2005-12-28 A |  | start no earlier than 2005-12-19 |
| 13 | Documentar procesos de GWT en un nivel 1 interconextándose las diferentes áreas de negocio | 13d? | 2005-12-19 A | 2006-01-04 |  | finish no earlier than 2006-01-04 |

Changed:

| ID | Task | Start | Finish | Duration | Complete | Total float | Predecessors | Other |
| --- | --- | --- | --- | --- | --- | --- | --- | --- |
| 1 | **Proyecto "e-orchestra"** |  | 2006-03-30 → 2006-03-03 (-27d) | 89d → 70d? | 9% → 41% |  |  |  |
| 2 | **Fase de Análisis** |  | 2005-12-28 → 2006-01-04 (+7d) | 23d → 28d? | 24% → 95% | 66d → 0d |  |  |
| 3 | **Levantamiento de la información** |  | 2005-12-28 → 2006-01-04 (+7d) | 23d → 28d? | 24% → 95% | 66d → 0d |  |  |
| 5 | **Entrevista por grupos responsables de las diferentes áreas de negocio de la empresa y de los subproyectos de e-orchestra** |  | 2005-12-28 → 2006-01-04 (+7d) | 18d → 23d? | 13% → 94% | 66d → 0d |  |  |
| 8 | **Determinar las necesidades del usuario para realizar su trabajo de manera óptima** |  | 2005-12-28 → 2006-01-04 (+7d) | 16d → 21d? | 6% → 93% | 66d → 0d |  | constraint finish no earlier than 2005-12-16 → none |
| 11 | **Documentar los procesos empresariales** | 2005-12-07 A → 2005-12-19 A (+12d) | 2005-12-28 → 2006-01-04 (+7d) | 16d → 13d? | 6% → 90% |  |  | was named Reconocer los procesos empresariales; constraint finish no earlier than 2005-12-16 → none |
| 14 | **Fase de Diseño** | 2005-12-29 → 2006-01-05 (+7d) | 2006-02-02 → 2006-02-09 (+7d) |  |  |  |  |  |
| 15 | Diseñar el sistema a implementar aplicando la metodología de desarrollo propuesta para la gerencia de proyectos de informática lo cual permitirá optimizar el seguimiento y desarrollo de los mismos | 2005-12-29 → 2006-01-05 (+7d) | 2006-02-01 → 2006-02-08 (+7d) |  |  |  |  |  |
| 16 | Diseñar la estructura de los documentos que en línea mostrarán los procedimientos asociados con el sistema. | 2006-01-19 → 2006-01-26 (+7d) | 2006-01-25 → 2006-02-01 (+7d) |  |  |  |  |  |
| 17 | Entregable: Interfaz del sistema y diseño de la estructura de la documentación de procedimientos | 2006-02-02 → 2006-02-09 (+7d) | 2006-02-02 → 2006-02-09 (+7d) |  |  |  |  |  |
| 18 | **Fase de Desarrollo** | 2006-02-03 → 2006-02-10 (+7d) | 2006-03-30 → 2006-03-03 (-27d) | 40d → 16d |  |  |  |  |
| 19 | Elaboración de un documento en línea de procedimientos que permita optimizar el desarrollo y seguimiento de proyectos de informática, a la empresa GWT | 2006-02-03 → 2006-02-10 (+7d) | 2006-03-29 → 2006-03-03 (-26d) | 39d → 16d |  |  |  |  |
| 20 | Entregable: Sistema, herramienta de software, que de soporte a la metodología de desarrollo propuesta | 2006-03-30 → 2006-03-03 (-27d) | 2006-03-30 → 2006-03-03 (-27d) |  |  |  | 19 → none | constraint none → start no earlier than 2006-03-03 |
