# ttgoportunidades

How a schedule from MS Project changed from version to version. A marks actual dates.

## Version 1 (saved 2005-12-13, file YYY20051213-4225024.mpp)

| ID | WBS | Task | Duration | Start | Finish | Predecessors | Complete | Total float | Constraint |
| --- | --- | --- | --- | --- | --- | --- | --- | --- | --- |
| 1 | 1 | **Gerencia oportunidades** | 34.5d? | 2005-11-23 A | 2006-01-10 |  | 4% | 0d |  |
| 3 |  | Inicio | 1d? | 2005-11-23 A | 2005-11-23 A |  | 100% |  | start no earlier than 2005-11-23 |
| 4 | 1.2 | **Definición del proceso** | 17.5d | 2005-11-29 | 2005-12-22 |  |  | 0d |  |
| 5 |  | Definición de métricas | 7d | 2005-11-29 | 2005-12-13 |  |  | 0d |  |
| 6 |  | Establecimiento de procedimientos | 7d | 2005-12-13 | 2005-12-22 | 5 |  | 0d |  |
| 7 | 1.3 | **Incorporación a 701** | 2d? | 2005-12-22 | 2005-12-26 | 6 |  | 0d |  |
| 8 |  | Definición de tablas | 1d? | 2005-12-22 | 2005-12-23 |  |  | 0d |  |
| 9 |  | Definición de Campos | 1d? | 2005-12-23 | 2005-12-26 | 8 |  | 0d |  |
| 10 |  | Prueba de Sistema | 10d | 2005-12-26 | 2006-01-09 | 9 |  | 0d |  |
| 11 |  | Cierre | 1d | 2006-01-09 | 2006-01-10 | 10 |  | 0d |  |

## Version 2 (saved 2006-01-24, file YYY20060124-1993053.mpp)

Last finish 2006-01-10 → 2006-03-02 (+51d). Complete tasks 1 → 3.

Added:

| ID | Task | Duration | Start | Finish | Predecessors | Constraint | Resources |
| --- | --- | --- | --- | --- | --- | --- | --- |
| 7 | Propuesta de Métricas | 25d | 2005-12-21 A | 2006-01-24 |  | finish no earlier than 2006-01-24 | V Riera |
| 9 | Definición de Métricas | 1d | 2006-01-12 A | 2006-01-25 |  | finish no earlier than 2006-01-24 |  |
| 12 | Puesta en producción del sistema | 10d | 2006-01-25 | 2006-02-07 |  |  |  |
| 14 | Aprobación del sistema | 5d | 2006-02-23 | 2006-03-01 | 13 |  | V Riera |

Changed:

| ID | Task | Start | Finish | Duration | Complete | Total float | Predecessors | Other |
| --- | --- | --- | --- | --- | --- | --- | --- | --- |
| 1 | **Gerencia oportunidades** |  | 2006-01-10 → 2006-03-02 (+51d) | 34.5d? → 72d? | 4% → 54% |  |  |  |
| 4 | **Definición del proceso** | 2005-11-29 A | 2005-12-22 → 2006-01-24 (+33d) | 17.5d → 41d? | 0% → 74% |  |  |  |
| 5 | Establecimiento de procesos | 2005-11-29 A | 2005-12-13 → 2006-01-20 A (+38d) | 7d → 35.5d | 0% → 100% | 0d → none |  | was named Definición de métricas |
| 6 | Establecimiento de procedimientos | 2005-12-13 A | 2005-12-22 → 2006-01-20 A (+29d) | 7d → 28.5d? | 0% → 100% | 0d → none |  | resources V Riera → none; baseline start 2005-12-13 → none; baseline finish 2005-12-21 → none |
| 8 | **Incorporación a 701** | 2005-12-22 → 2006-01-12 A (+21d) | 2005-12-26 → 2006-03-01 (+65d) | 2d? → 35d | 0% → 6% | 0d → 1d | 6 → 7 |  |
| 10 | Definición de tablas | 2005-12-22 → 2006-01-16 A (+25d) | 2005-12-23 → 2006-01-31 (+39d) | 1d? → 5d | 0% → 14% | 0d → 18.3d | none → 9 | constraint none → start no earlier than 2006-01-16 |
| 11 | Definición de Campos | 2005-12-23 → 2006-01-17 A (+25d) | 2005-12-26 → 2006-02-06 (+42d) | 1d? → 5d | 0% → 16% | 0d → 18.3d |  |  |
| 13 | Prueba de Sistema | 2005-12-26 → 2006-02-08 (+44d) | 2006-01-09 → 2006-02-22 (+44d) | 10d → 11d |  |  | 11 → 12 |  |
| 15 | Cierre | 2006-01-09 → 2006-03-02 (+52d) | 2006-01-10 → 2006-03-02 (+51d) |  |  |  | 13 → 14 |  |

## Version 3 (saved 2006-02-15, file YYY20060215-2771231.mpp)

Last finish stays 2006-03-02. Complete tasks 3 → 10.

Changed:

| ID | Task | Start | Finish | Duration | Complete | Total float | Other |
| --- | --- | --- | --- | --- | --- | --- | --- |
| 1 | **Gerencia oportunidades** |  |  |  | 54% → 99% |  |  |
| 4 | **Definición del proceso** |  | 2006-01-24 A |  | 74% → 100% | 0d → none |  |
| 7 | Propuesta de Métricas |  | 2006-01-24 A |  | 6% → 100% | 0d → none |  |
| 8 | **Incorporación a 701** |  | 2006-03-01 → 2006-02-23 A (-6d) | 35d → 31d | 6% → 100% | 1d → none |  |
| 9 | Definición de Métricas |  | 2006-01-25 A |  | 80% → 100% | 18.3d → none |  |
| 10 | Definición de tablas |  | 2006-01-31 → 2006-01-27 A (-4d) | 5d → 3d | 14% → 100% | 18.3d → none |  |
| 11 | Definición de Campos |  | 2006-02-06 → 2006-01-31 A (-6d) | 5d → 1d | 16% → 100% | 18.3d → none |  |
| 12 | Puesta en producción del sistema | 2006-01-25 A | 2006-02-07 → 2006-01-27 A (-11d) | 10d → 3d | 0% → 100% | 0d → none |  |
| 13 | Prueba de Sistema | 2006-02-08 A | 2006-02-22 A | 11d → 2d | 0% → 100% | 0d → none | resources O Lorenzo V Riera → V Riera |
| 14 | Aprobación del sistema | 2006-02-23 A | 2006-03-01 → 2006-02-23 A (-6d) | 5d → 1d | 0% → 100% | 0d → none |  |
| 15 | Cierre | 2006-03-02 A |  |  | 0% → 70% |  |  |
