# Cronograma

How a schedule from MS Project changed from version to version. A marks actual dates.

## Version 1 (saved 2008-11-04, file 20081104-1225815103.mpp)

| ID | WBS | Task | Duration | Start | Finish | Predecessors | Total float | Constraint |
| --- | --- | --- | --- | --- | --- | --- | --- | --- |
| 1 | 1 | **CRM Revensub** | 87.88d? | 2008-10-03 | 2009-03-10 |  | 0d |  |
| 2 |  | Análisis y modelaje de datos | 5d? | 2008-10-03 | 2008-10-09 |  | 82.88d | start no earlier than 2008-10-03 |
| 3 |  | Documento de Especificaciones | 4d? | 2008-10-29 | 2008-11-03 |  | 65.88d | start no earlier than 2008-10-29 |
| 4 | 1.3 | **Desarrollo** | 32.5d? | 2008-11-06 | 2009-01-26 |  | 0d |  |
| 5 |  | Validaciones Formularios | 5d? | 2008-11-06 | 2008-11-12 |  | 0d | start no earlier than 2008-11-06 |
| 6 |  | Página Principal | 5d? | 2008-11-13 | 2008-11-19 | 5 | 0d |  |
| 7 |  | Uso de plantillas | 6d? | 2008-11-20 | 2008-11-27 | 6 | 0d |  |
| 8 |  | Asignación de Responsables | 3d? | 2008-11-28 | 2008-12-02 | 7 | 0d |  |
| 9 |  | Mis Tareas | 2d? | 2008-12-03 | 2008-12-04 | 8 | 0d |  |
| 10 |  | Vista extendida Empresas | 1.5d? | 2008-12-05 | 2008-12-08 | 9 | 0d |  |
| 11 |  | Vista extendida Contactos | 1.5d? | 2008-12-08 | 2008-12-09 | 10 | 0d |  |
| 12 |  | Vista extendida Eventos | 1.5d? | 2008-12-10 | 2008-12-11 | 11 | 0d |  |
| 13 |  | Ingreso de Tareas a Interacicones, Eventos y Empresas | 3d? | 2008-12-11 | 2009-01-20 | 12 | 0d |  |
| 14 |  | Historial de cambios en tablas | 1d? | 2009-01-20 | 2009-01-21 | 13 | 0d |  |
| 15 |  | Perfiles de acceso | 2d? | 2009-01-21 | 2009-01-23 | 14 | 0d |  |
| 16 |  | Manejo Multiempresa | 1d? | 2009-01-23 | 2009-01-26 | 15 | 0d |  |
| 17 | 1.4 | **Reportes** | 6d? | 2009-01-26 | 2009-02-03 |  | 0d |  |
| 18 |  | Gestión de usuarios | 4d? | 2009-01-26 | 2009-01-30 | 4 | 0d |  |
| 19 |  | Prospectos | 2d? | 2009-01-30 | 2009-02-03 | 18 | 0d |  |
| 20 |  | Carga de datos de Contactos | 2d? | 2009-02-03 | 2009-02-05 | 17 | 0.38d |  |
| 21 |  | Guia de Usuario | 4d? | 2009-02-05 | 2009-02-11 | 20 | 0.38d |  |
| 22 |  | Certificación Cliente | 10d | 2009-02-11 | 2009-02-25 | 21 | 0.38d |  |
| 23 |  | Ajustes | 4d? | 2009-02-25 | 2009-03-03 | 22 | 0.38d |  |
| 24 |  | Documentación Técnica | 5d? | 2009-03-03 | 2009-03-10 | 23 | 0.38d |  |
| 25 |  | Puesta en Producción | 5d? | 2009-03-03 | 2009-03-10 | 23 | 0.38d |  |
| 26 | 1.11 | **Gerencia de Proyectos** | 25.38d? | 2009-02-03 | 2009-03-10 | 19 | 0d |  |
| 27 |  | Control y Seguimiento | 25d? | 2009-02-03 | 2009-03-10 |  | 0d | start no earlier than 2008-11-06 |
| 28 |  | Cierre | 0.38d? | 2009-03-10 | 2009-03-10 | 27 | 0d |  |

## Version 2 (saved 2009-02-03, file YYY20090209-5189040.mpp)

Last finish 2009-03-10 → 2009-03-18 (+8d). Complete tasks 0 → 5.

Added:

| ID | Task | Duration | Start | Finish | Predecessors | Resources |
| --- | --- | --- | --- | --- | --- | --- |
| 6 | Ajustes Nexus | 6d? | 2008-11-13 A | 2008-11-20 A | 5 | DR [50%] |

Changed:

| ID | Task | Start | Finish | Duration | Complete | Total float | Predecessors |
| --- | --- | --- | --- | --- | --- | --- | --- |
| 1 | **CRM Revensub** | 2008-10-03 A | 2009-03-10 → 2009-03-18 (+8d) | 87.88d? → 93.88d? | 0% → 30% |  |  |
| 2 | Análisis y modelaje de datos | 2008-10-03 A | 2008-10-09 A |  | 0% → 100% | 82.88d → none |  |
| 3 | Documento de Especificaciones | 2008-10-29 A | 2008-11-03 A |  | 0% → 100% | 65.88d → none |  |
| 4 | **Desarrollo** | 2008-11-06 A | 2009-01-26 → 2009-02-03 (+8d) | 32.5d? → 38.5d? | 0% → 43% |  |  |
| 5 | Validaciones Formularios | 2008-11-06 A | 2008-11-12 A |  | 0% → 100% | 0d → none |  |
| 7 | Página Principal | 2008-11-13 → 2008-11-21 A (+8d) | 2008-11-19 → 2008-11-27 A (+8d) |  | 0% → 100% | 0d → none | 5 → 6 |
| 8 | Uso de plantillas | 2008-11-20 → 2008-11-28 A (+8d) | 2008-11-27 → 2008-12-05 (+8d) |  | 0% → 10% |  |  |
| 9 | Asignación de Responsables | 2008-11-28 → 2008-12-08 (+10d) | 2008-12-02 → 2008-12-10 (+8d) |  |  |  |  |
| 10 | Mis Tareas | 2008-12-03 → 2008-12-11 (+8d) | 2008-12-04 → 2008-12-12 (+8d) |  |  |  |  |
| 11 | Vista extendida Empresas | 2008-12-05 → 2009-01-19 (+45d) | 2008-12-08 → 2009-01-20 (+43d) |  |  |  |  |
| 12 | Vista extendida Contactos | 2008-12-08 → 2009-01-20 (+43d) | 2008-12-09 → 2009-01-21 (+43d) |  |  |  |  |
| 13 | Vista extendida Eventos | 2008-12-10 → 2009-01-22 (+43d) | 2008-12-11 → 2009-01-23 (+43d) |  |  |  |  |
| 14 | Ingreso de Tareas a Interacicones, Eventos y Empresas | 2008-12-11 → 2009-01-23 (+43d) | 2009-01-20 → 2009-01-28 (+8d) |  |  |  |  |
| 15 | Historial de cambios en tablas | 2009-01-20 → 2009-01-28 (+8d) | 2009-01-21 → 2009-01-29 (+8d) |  |  |  |  |
| 16 | Perfiles de acceso | 2009-01-21 → 2009-01-29 (+8d) | 2009-01-23 → 2009-02-02 (+10d) |  |  |  |  |
| 17 | Manejo Multiempresa | 2009-01-23 → 2009-02-02 (+10d) | 2009-01-26 → 2009-02-03 (+8d) |  |  |  |  |
| 18 | **Reportes** | 2009-01-26 → 2009-02-03 (+8d) | 2009-02-03 → 2009-02-11 (+8d) |  |  |  |  |
| 19 | Gestión de usuarios | 2009-01-26 → 2009-02-03 (+8d) | 2009-01-30 → 2009-02-09 (+10d) |  |  |  |  |
| 20 | Prospectos | 2009-01-30 → 2009-02-09 (+10d) | 2009-02-03 → 2009-02-11 (+8d) |  |  |  |  |
| 21 | Carga de datos de Contactos | 2009-02-03 → 2009-02-11 (+8d) | 2009-02-05 → 2009-02-13 (+8d) |  |  |  |  |
| 22 | Guia de Usuario | 2009-02-05 → 2009-02-13 (+8d) | 2009-02-11 → 2009-02-19 (+8d) |  |  |  |  |
| 23 | Certificación Cliente | 2009-02-11 → 2009-02-19 (+8d) | 2009-02-25 → 2009-03-05 (+8d) |  |  |  |  |
| 24 | Ajustes | 2009-02-25 → 2009-03-05 (+8d) | 2009-03-03 → 2009-03-11 (+8d) |  |  |  |  |
| 25 | Documentación Técnica | 2009-03-03 → 2009-03-11 (+8d) | 2009-03-10 → 2009-03-18 (+8d) |  |  |  |  |
| 26 | Puesta en Producción | 2009-03-03 → 2009-03-11 (+8d) | 2009-03-10 → 2009-03-18 (+8d) |  |  |  |  |
| 27 | **Gerencia de Proyectos** | 2009-02-03 A | 2009-03-10 → 2009-03-18 (+8d) | 25.38d? → 31.38d? | 0% → 30% |  |  |
| 28 | Control y Seguimiento | 2009-02-03 A | 2009-03-10 → 2009-03-18 (+8d) | 25d? → 30d? | 0% → 30% |  | none → 3 |
| 29 | Cierre | 2009-03-10 → 2009-03-18 (+8d) | 2009-03-10 → 2009-03-18 (+8d) |  |  |  |  |
