# Proyecto CRM - Corporacion Union

How a schedule from MS Project changed from version to version. A marks actual dates.

## Version 1 (data date 2007-03-19, saved 2008-08-19, file YYY20080819-9988108.mpp)

| ID | WBS | Task | Duration | Start | Finish | Predecessors | Complete | Total float | Constraint |
| --- | --- | --- | --- | --- | --- | --- | --- | --- | --- |
| 1 | 1 | **Sito Web amigoscarental.com - Fase II** | 76.62d? | 2008-07-28 A | 2008-11-18 |  | 8% | 0d |  |
| 2 | 1.1 | **Inicio** | 0.25d | 2008-07-28 A | 2008-07-28 A |  | 100% |  |  |
| 3 |  | Reunión de Arranque (Kickoff) | 0.25d | 2008-07-28 A | 2008-07-28 A |  | 100% |  | start no earlier than 2008-07-28 |
| 4 | 1.2 | **Especificación de Requerimientos** | 12d | 2008-07-29 A | 2008-08-19 A |  | 100% |  |  |
| 5 |  | Elaboración del Informe Esp. de Req. y Matriz de Req. | 2d | 2008-07-29 A | 2008-07-30 A |  | 100% |  | start no earlier than 2008-07-29 |
| 6 |  | Ajustes al Informe Especificación de Requerimientos | 1d | 2008-08-06 A | 2008-08-06 A | 5 | 100% |  |  |
| 7 |  | Entrega de Especificación de Requerimientos para aprobación | 0d | 2008-08-06 A | 2008-08-06 A | 6 | 100% |  |  |
| 8 |  | Revisión por parte del Cliente | 9d | 2008-08-07 A | 2008-08-19 A | 7 | 100% |  |  |
| 9 |  | Aprobación del Informe Especificación de Requerimientos | 0d | 2008-08-19 A | 2008-08-19 A | 8 | 100% |  |  |
| 10 |  | Informe Especificación de Requerimientos Aprobado | 0d | 2008-08-19 | 2008-08-19 | 9 |  | 0d |  |
| 11 | 1.4 | **Configuración y Desarrollo** | 44.5d | 2008-08-21 | 2008-10-23 |  |  | 0.04d |  |
| 12 |  | Análisis y Diseño (incluye creación de tablas en BD) | 4d | 2008-08-21 | 2008-08-26 | 51 |  | 0.04d | finish no earlier than 2007-03-08 |
| 13 | 1.4.2 | **Reestructuración visual (F-ACR-01)** | 12d | 2008-08-28 | 2008-09-12 |  |  | 0.04d |  |
| 14 |  | Modificación de estructura actual - tres columnas | 2d | 2008-08-28 | 2008-08-29 | 12 |  | 0.04d |  |
| 15 |  | Reorganización de componentes existentes | 6d | 2008-09-01 | 2008-09-08 | 14 |  | 0.04d |  |
| 16 |  | Ajustes en CSS | 4d | 2008-09-09 | 2008-09-12 | 15 |  | 0.04d |  |
| 17 | 1.4.3 | **Reservación En-línea (F-ACR-02)** | 11d | 2008-09-15 | 2008-09-29 |  |  | 0.04d |  |
| 18 |  | Ajustes en Formulario de Solicitud de Reserva | 5d | 2008-09-15 | 2008-09-19 | 13 |  | 0.04d |  |
| 19 |  | Detección de Usuario autenticado | 4d | 2008-09-22 | 2008-09-25 | 18 |  | 0.04d |  |
| 20 |  | Email con Reservación | 2d | 2008-09-26 | 2008-09-29 | 19 |  | 0.04d |  |
| 21 | 1.4.4 | **Consulta de Reservaciones (F- ACR-04 )** | 3d | 2008-09-30 | 2008-10-02 |  |  | 0.04d |  |
| 22 |  | Ajustes en la consulta de Reservaciones del Backoffice | 1d | 2008-09-30 | 2008-09-30 | 17 |  | 0.04d |  |
| 23 |  | Ajustes en actualización de Reserva - Envío de Email a Cliente | 2d | 2008-10-01 | 2008-10-02 | 22 |  | 0.04d |  |
| 24 | 1.4.5 | **Consulta de Reservaciones por Sitio Web (F- ACR-03)** | 3.5d | 2008-10-03 | 2008-10-08 |  |  | 0.04d |  |
| 25 |  | Creación de opción de consulta | 0.5d | 2008-10-03 | 2008-10-03 | 21 |  | 0.04d |  |
| 26 |  | Listado de Reservas del Cliente (con su status y enlace a detalle) | 3d | 2008-10-03 | 2008-10-08 | 25 |  | 0.04d |  |
| 27 | 1.4.6 | **Pago de Reservación por Internet (F- ACR-03)** | 11d | 2008-10-08 | 2008-10-23 |  |  | 0.04d |  |
| 28 |  | Configuración de Boton de Pago de Todo1 | 1d | 2008-10-08 | 2008-10-09 | 24 |  | 0.04d |  |
| 29 |  | Boton de Pago desde listado de Reservaciones (para pagos pendientes) | 4d | 2008-10-09 | 2008-10-15 | 28 |  | 0.04d |  |
| 30 |  | Formulario para pago con TDC | 3d | 2008-10-15 | 2008-10-20 | 29 |  | 0.04d |  |
| 31 |  | Pruebas de pago y ajustes (con data de prueba con el Banco) | 3d | 2008-10-20 | 2008-10-23 | 30 |  | 0.04d |  |
| 32 |  | Pruebas Internas y Ajustes | 5d | 2008-10-23 | 2008-10-30 | 27 |  | 0.04d |  |
| 33 | 1.6 | **Documentación** | 6d? | 2008-10-30 | 2008-11-07 |  |  | 7.12d |  |
| 34 |  | Guia de Usuarios Módulo Reservaciones En Línea | 4d | 2008-10-30 | 2008-11-05 | 32 |  | 8.12d |  |
| 35 |  | Ajustes en Documento Técnico realizado en Fase I | 1d? | 2008-11-05 | 2008-11-06 | 34 |  | 7.12d |  |
| 36 |  | Documentos de Guía de Usuarios | 1d | 2008-11-06 | 2008-11-07 | 35 |  | 7.12d |  |
| 37 | 1.7 | **Adiestramiento** | 0.38d? | 2008-11-05 | 2008-11-05 |  |  | 8.75d |  |
| 38 |  | Presentación para adiestramiento | 0.12d? | 2008-11-05 | 2008-11-05 | 34 |  | 8.75d |  |
| 39 |  | Adiestramiento Módulo de Reservaciones En-Linea | 0.25d | 2008-11-05 | 2008-11-05 | 38 |  | 8.75d |  |
| 40 |  | Fase II de Sitio Web | 1d | 2008-10-30 | 2008-10-31 | 32 |  | 0.04d |  |
| 41 | 1.9 | **Pruebas de Certificación** | 9d | 2008-10-31 | 2008-11-13 |  |  | 0.04d |  |
| 42 |  | Realización de Pruebas de Funcionalidad por parte de Cliente | 5d | 2008-10-31 | 2008-11-07 | 40 |  | 0.04d |  |
| 43 |  | Realización de Ajustes recomendados | 4d | 2008-11-07 | 2008-11-13 | 42 |  | 0.04d |  |
| 44 |  | Certificación del Sistema | 0d | 2008-11-13 | 2008-11-13 | 43 |  | 0.04d |  |
| 45 | 1.10 | **Puesta en Producción** | 2.67d | 2008-11-13 | 2008-11-18 |  |  | 0.04d |  |
| 46 |  | Implantación/Entonación | 1.67d | 2008-11-13 | 2008-11-17 | 41 |  | 0.04d |  |
| 47 |  | Sistema en Producción | 1d | 2008-11-17 | 2008-11-18 | 46 |  | 0.04d |  |
| 48 | 1.11 | **Cierre** | 0.42d | 2008-11-18 | 2008-11-18 |  |  | 0.04d |  |
| 49 |  | Preparación y envio de Acta de Cierre | 0.42d | 2008-11-18 | 2008-11-18 | 45 |  | 0.04d |  |
| 50 | 1.12 | **Gerencia de Proyecto** | 63.62d | 2008-08-20 | 2008-11-18 |  |  | 0d |  |
| 51 |  | Planificación | 1d | 2008-08-20 | 2008-08-20 | 10 |  | 0d |  |
| 52 |  | Control y Seguimiento | 62.5d | 2008-08-21 | 2008-11-18 | 51 |  | 0d |  |

## Version 2 (data date 2007-03-19, saved 2008-10-10, file 20081010-1223667668.mpp)

Last finish 2008-11-18 → 2009-02-23 (+97d). Complete tasks 6 → 12.

Removed: 36 Documentos de Guía de Usuarios

Changed:

| ID | Task | Start | Finish | Duration | Complete | Total float | Other |
| --- | --- | --- | --- | --- | --- | --- | --- |
| 1 | **Sito Web amigoscarental.com - Fase II** |  | 2008-11-18 → 2009-02-23 (+97d) | 76.62d? → 127.75d? | 8% → 34% |  |  |
| 2 | **Inicio** |  |  | 0.25d → 0.12d |  |  |  |
| 4 | **Especificación de Requerimientos** |  |  | 12d → 11.75d |  |  |  |
| 10 | Informe Especificación de Requerimientos Aprobado | 2008-08-19 A | 2008-08-19 A |  | 0% → 100% | 0d → none |  |
| 11 | **Configuración y Desarrollo** | 2008-08-21 → 2008-09-16 A (+26d) | 2008-10-23 → 2008-12-15 (+53d) | 44.5d → 64.83d | 0% → 31% | 0.04d → 0.08d |  |
| 12 | Análisis y Diseño (incluye creación de tablas en BD) | 2008-08-21 → 2008-09-16 A (+26d) | 2008-08-26 → 2008-09-19 A (+24d) |  | 0% → 100% | 0.04d → none | constraint finish no earlier than 2007-03-08 → start no earlier than 2008-09-16; resources JS [50%] → MV [50%] |
| 13 | **Reestructuración visual (F-ACR-01)** | 2008-08-28 → 2008-09-22 A (+25d) | 2008-09-12 → 2008-10-13 A (+31d) | 12d → 16d | 0% → 100% | 0.04d → none |  |
| 14 | Modificación de estructura actual - tres columnas | 2008-08-28 → 2008-09-22 A (+25d) | 2008-08-29 → 2008-09-25 A (+27d) | 2d → 4d | 0% → 100% | 0.04d → none | resources JS [50%] → MV [50%] |
| 15 | Reorganización de componentes existentes | 2008-09-01 → 2008-09-26 A (+25d) | 2008-09-08 → 2008-10-06 A (+28d) | 6d → 7d | 0% → 100% | 0.04d → none | resources JS [50%] → MV [50%] |
| 16 | Ajustes en CSS | 2008-09-09 → 2008-10-07 A (+28d) | 2008-09-12 → 2008-10-13 A (+31d) | 4d → 5d | 0% → 100% | 0.04d → none | resources JS [50%] → MV [50%] |
| 17 | **Reservación En-línea (F-ACR-02)** | 2008-09-15 → 2008-10-14 (+29d) | 2008-09-29 → 2008-11-06 (+38d) | 11d → 18d |  | 0.04d → 0.08d |  |
| 18 | Ajustes en Formulario de Solicitud de Reserva | 2008-09-15 → 2008-10-14 (+29d) | 2008-09-19 → 2008-10-27 (+38d) | 5d → 10d |  | 0.04d → 0.08d | resources JS [50%] → MV [50%] |
| 19 | Detección de Usuario autenticado | 2008-09-22 → 2008-10-28 (+36d) | 2008-09-25 → 2008-11-03 (+39d) | 4d → 5d |  | 0.04d → 0.08d | resources JS [50%] → MV [50%] |
| 20 | Email con Reservación | 2008-09-26 → 2008-11-04 (+39d) | 2008-09-29 → 2008-11-06 (+38d) | 2d → 3d |  | 0.04d → 0.08d | resources JS [50%] → MV [50%] |
| 21 | **Consulta de Reservaciones (F- ACR-04 )** | 2008-09-30 → 2008-11-07 (+38d) | 2008-10-02 → 2008-11-17 (+46d) | 3d → 7d |  | 0.04d → 0.08d |  |
| 22 | Ajustes en la consulta de Reservaciones del Backoffice | 2008-09-30 → 2008-11-07 (+38d) | 2008-09-30 → 2008-11-11 (+42d) | 1d → 3d |  | 0.04d → 0.08d | resources JS [50%] → MV [50%] |
| 23 | Ajustes en actualización de Reserva - Envío de Email a Cliente | 2008-10-01 → 2008-11-12 (+42d) | 2008-10-02 → 2008-11-17 (+46d) | 2d → 4d |  | 0.04d → 0.08d | resources JS [50%] → MV [50%] |
| 24 | **Consulta de Reservaciones por Sitio Web (F- ACR-03)** | 2008-10-03 → 2008-11-18 (+46d) | 2008-10-08 → 2008-11-24 (+47d) | 3.5d → 4.5d |  | 0.04d → 0.08d |  |
| 25 | Creación de opción de consulta | 2008-10-03 → 2008-11-18 (+46d) | 2008-10-03 → 2008-11-18 (+46d) |  |  | 0.04d → 0.08d | resources JS [50%] → MV [50%] |
| 26 | Listado de Reservas del Cliente (con su status y enlace a detalle) | 2008-10-03 → 2008-11-18 (+46d) | 2008-10-08 → 2008-11-24 (+47d) | 3d → 4d |  | 0.04d → 0.08d | resources JS [50%] → MV [50%] |
| 27 | **Pago de Reservación por Internet (F- ACR-03)** | 2008-10-08 → 2008-11-24 (+47d) | 2008-10-23 → 2008-12-15 (+53d) | 11d → 15.33d |  | 0.04d → 0.08d |  |
| 28 | Configuración de Boton de Pago de Todo1 | 2008-10-08 → 2008-11-24 (+47d) | 2008-10-09 → 2008-11-27 (+49d) | 1d → 3.33d |  | 0.04d → 0.08d | resources OP [25%]; JS [50%] → OP [25%]; MV [50%] |
| 29 | Boton de Pago desde listado de Reservaciones (para pagos pendientes) | 2008-10-09 → 2008-11-27 (+49d) | 2008-10-15 → 2008-12-03 (+49d) |  |  | 0.04d → 0.08d | resources JS [50%] → MV [50%] |
| 30 | Formulario para pago con TDC | 2008-10-15 → 2008-12-03 (+49d) | 2008-10-20 → 2008-12-09 (+50d) | 3d → 4d |  | 0.04d → 0.08d | resources JS [50%] → MV [50%] |
| 31 | Pruebas de pago y ajustes (con data de prueba con el Banco) | 2008-10-20 → 2008-12-09 (+50d) | 2008-10-23 → 2008-12-15 (+53d) | 3d → 4d |  | 0.04d → 0.08d | resources JS [50%] → MV [50%] |
| 32 | Pruebas Internas y Ajustes | 2008-10-23 → 2008-12-15 (+53d) | 2008-10-30 → 2009-02-04 (+97d) | 5d → 18.75d |  | 0.04d → 0.08d | resources JS [50%]; MR [30%] → MV [50%]; MR [10%] |
| 33 | **Documentación** | 2008-10-30 → 2009-02-04 (+97d) | 2008-11-07 → 2009-02-13 (+98d) | 6d? → 7d? |  | 7.12d → 6.17d |  |
| 34 | Guia de Usuarios Módulo Reservaciones En Línea | 2008-10-30 → 2009-02-04 (+97d) | 2008-11-05 → 2009-02-11 (+98d) | 4d → 5d |  | 8.12d → 6.17d | resources JS [50%] → MV [50%] |
| 35 | Ajustes en Documento Técnico realizado en Fase I | 2008-11-05 → 2009-02-11 (+98d) | 2008-11-06 → 2009-02-13 (+99d) | 1d? → 2d? |  | 7.12d → 6.17d | resources JS [50%] → MV [50%] |
| 36 | **Adiestramiento** | 2008-11-05 → 2009-02-11 (+98d) | 2008-11-05 → 2009-02-12 (+99d) | 0.38d? → 0.5d? |  | 8.75d → 7.67d |  |
| 37 | Presentación para adiestramiento | 2008-11-05 → 2009-02-11 (+98d) | 2008-11-05 → 2009-02-11 (+98d) | 0.12d? → 0.25d? |  | 8.75d → 7.67d |  |
| 38 | Adiestramiento Módulo de Reservaciones En-Linea | 2008-11-05 → 2009-02-11 (+98d) | 2008-11-05 → 2009-02-12 (+99d) |  |  | 8.75d → 7.67d |  |
| 39 | Fase II de Sitio Web | 2008-10-30 → 2009-02-04 (+97d) | 2008-10-31 → 2009-02-05 (+97d) |  |  | 0.04d → 0.08d |  |
| 40 | **Pruebas de Certificación** | 2008-10-31 → 2009-02-05 (+97d) | 2008-11-13 → 2009-02-18 (+97d) |  |  | 0.04d → 0.08d |  |
| 41 | Realización de Pruebas de Funcionalidad por parte de Cliente | 2008-10-31 → 2009-02-05 (+97d) | 2008-11-07 → 2009-02-12 (+97d) |  |  | 0.04d → 0.08d |  |
| 42 | Realización de Ajustes recomendados | 2008-11-07 → 2009-02-12 (+97d) | 2008-11-13 → 2009-02-18 (+97d) |  |  | 0.04d → 0.08d | resources JS [50%] → MV [50%] |
| 43 | Certificación del Sistema | 2008-11-13 → 2009-02-18 (+97d) | 2008-11-13 → 2009-02-18 (+97d) |  |  | 0.04d → 0.08d |  |
| 44 | **Puesta en Producción** | 2008-11-13 → 2009-02-18 (+97d) | 2008-11-18 → 2009-02-23 (+97d) |  |  | 0.04d → 0.08d |  |
| 45 | Implantación/Entonación | 2008-11-13 → 2009-02-18 (+97d) | 2008-11-17 → 2009-02-20 (+95d) |  |  | 0.04d → 0.08d |  |
| 46 | Sistema en Producción | 2008-11-17 → 2009-02-20 (+95d) | 2008-11-18 → 2009-02-23 (+97d) |  |  | 0.04d → 0.08d |  |
| 47 | **Cierre** | 2008-11-18 → 2009-02-23 (+97d) | 2008-11-18 → 2009-02-23 (+97d) |  |  | 0.04d → 0.08d |  |
| 48 | Preparación y envio de Acta de Cierre | 2008-11-18 → 2009-02-23 (+97d) | 2008-11-18 → 2009-02-23 (+97d) |  |  | 0.04d → 0.08d |  |
| 49 | **Gerencia de Proyecto** | 2008-08-20 → 2008-08-19 A (-1d) | 2008-11-18 → 2009-02-23 (+97d) | 63.62d → 115d | 0% → 41% |  |  |
| 50 | Planificación | 2008-08-20 → 2008-08-19 A (-1d) | 2008-08-20 A |  | 0% → 100% | 0d → none |  |
| 51 | Control y Seguimiento | 2008-08-21 → 2008-08-20 A (-1d) | 2008-11-18 → 2009-02-23 (+97d) | 62.5d → 113.88d | 0% → 40% |  |  |

## Version 3 (data date 2007-03-19, saved 2009-02-07, file YYY20090209-6937561.mpp)

Last finish 2009-02-23 → 2009-03-05 (+10d). Complete tasks 12 → 18.

Added:

| ID | Task | Duration | Start | Finish | Constraint | Resources |
| --- | --- | --- | --- | --- | --- | --- |
| 19 | Revisión del Sistema (aprendiendo) | 2.88d? | 2008-11-11 A | 2008-11-13 A | start no earlier than 2008-11-11 | EV [50%] |

Changed:

| ID | Task | Start | Finish | Duration | Complete | Total float | Predecessors | Other |
| --- | --- | --- | --- | --- | --- | --- | --- | --- |
| 1 | **Sito Web amigoscarental.com - Fase II** |  | 2009-02-23 → 2009-03-05 (+10d) | 127.75d? → 131.62d? | 34% → 70% |  |  |  |
| 11 | **Configuración y Desarrollo** |  | 2008-12-15 → 2009-02-04 (+51d) | 64.83d → 79.21d? | 31% → 73% | 0.08d → 2.08d |  |  |
| 12 | Análisis y Diseño (incluye creación de tablas en BD) |  |  | 4d → 3.88d |  |  |  | resources MV [50%] → MV [51.6%] |
| 14 | Modificación de estructura actual - tres columnas |  |  | 4d → 3.88d |  |  |  | resources MV [50%] → MV [51.6%] |
| 15 | Reorganización de componentes existentes |  |  | 7d → 6.88d |  |  |  | resources MV [50%] → MV [50.9%] |
| 16 | Ajustes en CSS |  |  | 5d → 4.88d |  |  |  | resources MV [50%] → MV [51.3%] |
| 17 | **Reservación En-línea (F-ACR-02)** | 2008-10-14 A | 2008-11-06 → 2008-11-27 A (+21d) | 18d → 32.38d? | 0% → 100% | 0.08d → none |  |  |
| 18 | Ajustes en Formulario de Solicitud de Reserva | 2008-10-14 A | 2008-10-27 A | 10d → 9.99d | 0% → 100% | 0.08d → none |  |  |
| 20 | Detección de Usuario autenticado | 2008-10-28 → 2008-11-13 A (+16d) | 2008-11-03 → 2008-11-20 A (+17d) |  | 0% → 100% | 0.08d → none | 18 → 19 | resources MV [50%] → EV [50%] |
| 21 | Email con Reservación | 2008-11-04 → 2008-11-20 A (+16d) | 2008-11-06 → 2008-11-27 A (+21d) | 3d → 4.5d | 0% → 100% | 0.08d → none |  | resources MV [50%] → EV [50%] |
| 22 | **Consulta de Reservaciones (F- ACR-04 )** | 2008-11-07 → 2008-11-27 A (+20d) | 2008-11-17 → 2008-12-08 A (+21d) |  | 0% → 100% | 0.08d → none |  |  |
| 23 | Ajustes en la consulta de Reservaciones del Backoffice | 2008-11-07 → 2008-11-27 A (+20d) | 2008-11-11 → 2008-12-02 A (+21d) |  | 0% → 100% | 0.08d → none |  | resources MV [50%] → EV [50%] |
| 24 | Ajustes en actualización de Reserva - Envío de Email a Cliente | 2008-11-12 → 2008-12-02 A (+20d) | 2008-11-17 → 2008-12-08 A (+21d) |  | 0% → 100% | 0.08d → none |  | resources MV [50%] → EV [50%] |
| 25 | **Consulta de Reservaciones por Sitio Web (F- ACR-03)** | 2008-11-18 → 2008-12-08 A (+20d) | 2008-11-24 → 2008-12-12 (+18d) |  | 0% → 80% | 0.08d → 2.08d |  |  |
| 26 | Creación de opción de consulta | 2008-11-18 → 2008-12-08 A (+20d) | 2008-11-18 → 2008-12-08 (+20d) |  | 0% → 80% | 0.08d → 5.28d |  | resources MV [50%] → EV [50%] |
| 27 | Listado de Reservas del Cliente (con su status y enlace a detalle) | 2008-11-18 → 2008-12-08 A (+20d) | 2008-11-24 → 2008-12-12 (+18d) |  | 0% → 80% | 0.08d → 2.08d |  | resources MV [50%] → EV [50%] |
| 28 | **Pago de Reservación por Internet (F- ACR-03)** | 2008-11-24 → 2008-12-12 (+18d) | 2008-12-15 → 2009-02-04 (+51d) |  |  | 0.08d → 2.08d |  |  |
| 29 | Configuración de Boton de Pago de Todo1 | 2008-11-24 → 2008-12-12 (+18d) | 2008-11-27 → 2009-01-19 (+53d) | 3.33d → 6.54d |  | 0.08d → 2.08d |  | resources OP [25%]; MV [50%] → OP [25%]; EV [50%] |
| 30 | Boton de Pago desde listado de Reservaciones (para pagos pendientes) | 2008-11-27 → 2009-01-19 (+53d) | 2008-12-03 → 2009-01-23 (+51d) |  |  | 0.08d → 2.08d |  | resources MV [50%] → EV [50%] |
| 31 | Formulario para pago con TDC | 2008-12-03 → 2009-01-23 (+51d) | 2008-12-09 → 2009-01-29 (+51d) |  |  | 0.08d → 2.08d |  | resources MV [50%] → EV [50%] |
| 32 | Pruebas de pago y ajustes (con data de prueba con el Banco) | 2008-12-09 → 2009-01-29 (+51d) | 2008-12-15 → 2009-02-04 (+51d) |  |  | 0.08d → 2.08d |  | resources MV [50%] → EV [50%] |
| 33 | Pruebas Internas y Ajustes | 2008-12-15 → 2009-02-04 A (+51d) | 2009-02-04 → 2009-02-16 (+12d) | 18.75d → 8.33d | 0% → 25% | 0.08d → 0d |  | resources MV [50%]; MR [10%] → MR [10%]; EV [50%] |
| 34 | **Documentación** | 2009-02-04 → 2009-02-16 (+12d) | 2009-02-13 → 2009-02-26 (+13d) | 7d? → 8d? |  | 6.17d → 5.08d |  |  |
| 35 | Guia de Usuarios Módulo Reservaciones En Línea | 2009-02-04 → 2009-02-16 (+12d) | 2009-02-11 → 2009-02-24 (+13d) | 5d → 6d |  | 6.17d → 5.08d |  | resources MV [50%] → EV [50%] |
| 36 | Ajustes en Documento Técnico realizado en Fase I | 2009-02-11 → 2009-02-24 (+13d) | 2009-02-13 → 2009-02-26 (+13d) |  |  | 6.17d → 5.08d |  | resources MV [50%] → EV [50%] |
| 37 | **Adiestramiento** | 2009-02-11 → 2009-02-24 (+13d) | 2009-02-12 → 2009-02-25 (+13d) |  |  | 7.67d → 6.58d |  |  |
| 38 | Presentación para adiestramiento | 2009-02-11 → 2009-02-24 (+13d) | 2009-02-11 → 2009-02-24 (+13d) |  |  | 7.67d → 6.58d |  |  |
| 39 | Adiestramiento Módulo de Reservaciones En-Linea | 2009-02-11 → 2009-02-24 (+13d) | 2009-02-12 → 2009-02-25 (+13d) |  |  | 7.67d → 6.58d |  |  |
| 40 | Fase II de Sitio Web | 2009-02-04 → 2009-02-16 (+12d) | 2009-02-05 → 2009-02-17 (+12d) |  |  | 0.08d → 0d |  |  |
| 41 | **Pruebas de Certificación** | 2009-02-05 → 2009-02-17 (+12d) | 2009-02-18 → 2009-03-02 (+12d) |  |  | 0.08d → 0d |  |  |
| 42 | Realización de Pruebas de Funcionalidad por parte de Cliente | 2009-02-05 → 2009-02-17 (+12d) | 2009-02-12 → 2009-02-24 (+12d) |  |  | 0.08d → 0d |  |  |
| 43 | Realización de Ajustes recomendados | 2009-02-12 → 2009-02-24 (+12d) | 2009-02-18 → 2009-03-02 (+12d) |  |  | 0.08d → 0d |  | resources MV [50%] → EV [50%] |
| 44 | Certificación del Sistema | 2009-02-18 → 2009-03-02 (+12d) | 2009-02-18 → 2009-03-02 (+12d) |  |  | 0.08d → 0d |  |  |
| 45 | **Puesta en Producción** | 2009-02-18 → 2009-03-02 (+12d) | 2009-02-23 → 2009-03-05 (+10d) |  |  | 0.08d → 0d |  |  |
| 46 | Implantación/Entonación | 2009-02-18 → 2009-03-02 (+12d) | 2009-02-20 → 2009-03-04 (+12d) |  |  | 0.08d → 0d |  |  |
| 47 | Sistema en Producción | 2009-02-20 → 2009-03-04 (+12d) | 2009-02-23 → 2009-03-05 (+10d) |  |  | 0.08d → 0d |  |  |
| 48 | **Cierre** | 2009-02-23 → 2009-03-05 (+10d) | 2009-02-23 → 2009-03-05 (+10d) |  |  | 0.08d → 0d |  |  |
| 49 | Preparación y envio de Acta de Cierre | 2009-02-23 → 2009-03-05 (+10d) | 2009-02-23 → 2009-03-05 (+10d) |  |  | 0.08d → 0d |  |  |
| 50 | **Gerencia de Proyecto** |  | 2009-02-23 → 2009-03-04 (+9d) | 115d → 117.85d | 41% → 80% | 0d → 1.02d |  |  |
| 52 | Control y Seguimiento |  | 2009-02-23 → 2009-03-04 (+9d) | 113.88d → 116.73d | 40% → 80% | 0d → 1.02d |  | resources MR [6%] → MR [6.3%] |
