# Cronograma

How a schedule from MS Project changed from version to version. A marks actual dates.

## Version 1 (saved 2008-10-10, file 20081010-1223667865.mpp)

| ID | WBS | Task | Duration | Start | Finish | Predecessors | Complete | Total float | Constraint |
| --- | --- | --- | --- | --- | --- | --- | --- | --- | --- |
| 1 | 1 | **CRM HiveFoods** | 43d? | 2008-10-06 A | 2008-12-03 |  | 11% | 0d |  |
| 2 |  | Ajustes Registro Sanitario | 2d? | 2008-10-06 A | 2008-10-07 A |  | 100% |  | start no earlier than 2008-10-06 |
| 3 |  | Inclusión de Importador | 4d? | 2008-10-08 A | 2008-10-13 | 2 | 75% | 0d |  |
| 4 |  | Inclusión de Presentación | 4d? | 2008-10-14 | 2008-10-17 | 3 |  | 0d |  |
| 5 |  | Proceso de Análisis de Laboratorio | 5d? | 2008-10-20 | 2008-10-24 | 4 |  | 0d |  |
| 6 |  | Registro y proceso de CPE | 5d? | 2008-10-27 | 2008-10-31 | 5 |  | 0d |  |
| 7 |  | Reportes | 5d? | 2008-11-03 | 2008-11-07 | 6 |  | 0d |  |
| 8 |  | Alarmas | 5d? | 2008-11-10 | 2008-11-14 | 7 |  | 0d |  |
| 9 |  | Pruebas y ajustes | 3d? | 2008-11-17 | 2008-11-19 | 8 |  | 0d |  |
| 10 |  | Documento Guía de Usuario | 4d? | 2008-11-20 | 2008-11-25 | 9 |  | 0d |  |
| 11 |  | Pruebas de Certificación del Cliente | 4d | 2008-11-26 | 2008-12-01 | 10 |  | 2d |  |
| 12 |  | Documento Técnico | 4d? | 2008-11-26 | 2008-12-01 | 10 |  | 0d |  |
| 13 |  | Puesta en Producción | 1d? | 2008-12-02 | 2008-12-02 | 12 |  | 0d |  |
| 14 |  | Cierre | 1d? | 2008-12-03 | 2008-12-03 | 13 |  | 0d |  |

## Version 2 (saved 2009-02-03, file YYY20090209-7906552.mpp)

Last finish stays 2008-12-03. Complete tasks 1 → 10.

Changed:

| ID | Task | Start | Finish | Complete | Total float |
| --- | --- | --- | --- | --- | --- |
| 1 | **CRM HiveFoods** |  |  | 11% → 91% |  |
| 3 | Inclusión de Importador |  | 2008-10-13 A | 75% → 100% | 0d → none |
| 4 | Inclusión de Presentación | 2008-10-14 A | 2008-10-17 A | 0% → 100% | 0d → none |
| 5 | Proceso de Análisis de Laboratorio | 2008-10-20 A | 2008-10-24 A | 0% → 100% | 0d → none |
| 6 | Registro y proceso de CPE | 2008-10-27 A | 2008-10-31 → 2008-11-03 A (+3d) | 0% → 100% | 0d → none |
| 7 | Reportes | 2008-11-03 A | 2008-11-07 → 2008-11-10 A (+3d) | 0% → 100% | 0d → none |
| 8 | Alarmas | 2008-11-10 A | 2008-11-14 A | 0% → 100% | 0d → none |
| 9 | Pruebas y ajustes | 2008-11-17 A | 2008-11-19 A | 0% → 100% | 0d → none |
| 10 | Documento Guía de Usuario | 2008-11-20 A | 2008-11-25 A | 0% → 100% | 0d → none |
| 11 | Pruebas de Certificación del Cliente | 2008-11-26 A | 2008-12-01 A | 0% → 100% | 2d → none |
| 12 | Documento Técnico | 2008-11-26 A |  | 0% → 50% |  |
