# Nuevo Pendientes-Factibles

How a schedule from MS Project changed from version to version. A marks actual dates.

## Version 1 (saved 2008-10-01, file 20081010-1223668561.mpp)

| ID | WBS | Task | Duration | Start | Finish | Predecessors | Complete | Total float | Constraint |
| --- | --- | --- | --- | --- | --- | --- | --- | --- | --- |
| 1 | 1 | **Cines Unidos** | 80.75d? | 2008-09-23 A | 2009-02-06 |  | 11% | 0d |  |
| 2 | 1.1 | **Fase III - Integración** | 66.04d? | 2008-09-23 A | 2009-01-19 |  | 7% | 0.71d |  |
| 3 |  | Análisis de integraciones (ambiente local y directorios virtuales) | 4d? | 2008-09-23 A | 2008-09-26 A |  | 100% |  | start no earlier than 2008-09-23 |
| 4 |  | Migración a N2C 5.1 (en pippin y en tecnologiainternet) | 1.82d? | 2008-10-01 | 2008-10-02 |  |  | 59.68d | start no earlier than 2008-10-01 |
| 5 |  | Ajustes de CRM por cambio de versión y por ambiente Windows | 8.33d? | 2008-10-06 | 2008-10-16 | 10 |  | 49.42d |  |
| 6 | 1.1.4 | **Cambios Módulo Contacto** | 11d? | 2008-09-29 A | 2008-10-13 |  | 18% | 51.75d |  |
| 7 |  | Datos nuevos en Formulario | 1d? | 2008-09-29 A | 2008-09-29 A | 3 | 100% |  |  |
| 8 |  | Datos nuevos en detalle de contacto y en email | 1d? | 2008-09-30 A | 2008-09-30 A | 7 | 100% |  |  |
| 9 |  | Cambio en valores de Lista de Categorías y asociación grupos contactos | 2d? | 2008-10-01 | 2008-10-02 | 8 |  | 0.71d |  |
| 10 |  | Pruebas y ajustes | 1d? | 2008-10-03 | 2008-10-03 | 9 |  | 0.71d |  |
| 11 |  | Pruebas certificación por parte de Cines Unidos | 4d | 2008-10-06 | 2008-10-09 | 10 |  | 53.75d |  |
| 12 |  | Puesta en producción | 1d? | 2008-10-10 | 2008-10-10 | 15 |  | 0.71d |  |
| 13 |  | Módulo de Contacto en producción | 1d? | 2008-10-13 | 2008-10-13 | 12 |  | 51.75d |  |
| 14 | 1.1.5 | **Integración Sitio Web** | 7d? | 2008-10-06 | 2008-10-14 |  |  | 0.71d |  |
| 15 |  | Ajustes | 4d? | 2008-10-06 | 2008-10-09 | 10 |  | 0.71d |  |
| 16 |  | Implantación y pruebas en Pippin | 2d? | 2008-10-13 | 2008-10-14 | 12 |  | 0.71d |  |
| 17 | 1.1.6 | **Integración Tiendas Cines Unidos** | 7d? | 2008-10-10 | 2008-10-20 |  |  | 46.75d |  |
| 18 |  | Ajustes | 5d? | 2008-10-10 | 2008-10-16 | 15 |  | 46.75d |  |
| 19 |  | Implantación y pruebas en Pippin | 2d? | 2008-10-17 | 2008-10-20 | 18 |  | 46.75d |  |
| 20 | 1.1.7 | **Integración Transacciones** | 8d? | 2008-10-15 | 2008-10-24 |  |  | 0.71d |  |
| 21 |  | Desarrollo | 6d? | 2008-10-15 | 2008-10-22 | 14 |  | 0.71d |  |
| 22 |  | Implantación y Pruebas en Pippin | 2d? | 2008-10-23 | 2008-10-24 | 21 |  | 0.71d |  |
| 23 |  | Documentación Diccionario de Datos Vista | 1d? | 2008-10-03 | 2008-10-03 |  |  | 17.4d | start no earlier than 2008-10-03 |
| 24 |  | Integración Vista (Transacciones de Sitio Web) | 16.67d? | 2008-10-27 | 2008-11-18 | 23, 20 |  | 0.71d |  |
| 25 |  | Documentación Diccionario de Datos Vista | 1d? | 2008-10-10 | 2008-10-10 |  |  | 29.07d | start no earlier than 2008-10-10 |
| 26 |  | Integración CC-Vista (Clientes) | 16.67d? | 2008-11-18 | 2008-12-11 | 25, 24 |  | 0.71d |  |
| 27 |  | Documento Guia de Configuración de Integraciones | 4d? | 2008-12-11 | 2008-12-17 | 26 |  | 0.71d |  |
| 28 |  | Pruebas internas y Ajustes | 4.71d | 2008-12-17 | 2009-01-19 | 27 |  | 0.71d |  |
| 29 |  | Migración de Programas de Integración a Pippin (dir desarrollo) | 2d | 2009-01-19 | 2009-01-21 | 2 |  | 0.71d |  |
| 30 |  | Preparación Pruebas de Certificación | 3d | 2009-01-21 | 2009-01-26 | 29 |  | 0.71d |  |
| 31 |  | Apoyo en Pruebas de Certificación | 5d | 2009-01-26 | 2009-02-02 | 30 |  | 4.71d |  |
| 32 |  | Pruebas de Certificación por parte de Cines Unidos | 5d | 2009-01-26 | 2009-02-02 | 30 |  | 0.71d |  |
| 33 |  | Ajustes | 2d? | 2009-02-02 | 2009-02-04 | 32 |  | 0.71d |  |
| 34 |  | Verificación de Ajustes por parte de Cines Unidos | 1d | 2009-02-04 | 2009-02-05 | 33 |  | 0.71d |  |
| 35 |  | Pase a Producción de Integraciones | 1d | 2009-02-05 | 2009-02-06 | 34 |  | 0.71d |  |
| 36 |  | CRM completo en Producción | 0d | 2009-02-06 | 2009-02-06 | 35 |  | 0.71d |  |
| 37 |  | Gerencia de Proyectos | 66.25d | 2008-09-23 A | 2009-02-06 |  | 20% | 0d | start no earlier than 2008-09-23 |

## Version 2 (saved 2009-01-15, file YYY20090209-9163977.mpp)

Last finish 2009-02-06 → 2008-12-11 (-57d). Complete tasks 3 → 19.

Added:

| ID | Task | Duration | Start | Finish | Constraint | Resources |
| --- | --- | --- | --- | --- | --- | --- |
| 3 | Actividades Previas al 23 Sept | 59.25d? | 2008-07-01 A | 2008-09-22 A | finish no earlier than 2008-09-22 | DS [50%] |

Changed:

| ID | Task | Start | Finish | Duration | Complete | Total float | Predecessors | Other |
| --- | --- | --- | --- | --- | --- | --- | --- | --- |
| 1 | **Cines Unidos** | 2008-09-23 A → 2008-07-01 A (-84d) | 2009-02-06 → 2008-12-11 (-57d) | 80.75d? → 116.62d? | 11% → 86% |  |  |  |
| 2 | **Fase III - Integración** | 2008-09-23 A → 2008-07-01 A (-84d) | 2009-01-19 → 2008-11-19 (-61d) | 66.04d? → 100.33d? | 7% → 91% | 0.71d → 6.29d |  |  |
| 5 | Migración a N2C 5.1 (en pippin y en tecnologiainternet) | 2008-10-01 A | 2008-10-02 A |  | 0% → 100% | 59.68d → none |  |  |
| 6 | Ajustes de CRM por cambio de versión y por ambiente Windows | 2008-10-06 A | 2008-10-16 → 2008-10-13 A (-3d) | 8.33d? → 5.56d? | 0% → 100% | 49.42d → none |  | resources DS [50%]; DS2 [30%] → DS [90%] |
| 7 | **Cambios Módulo Contacto** |  | 2008-10-13 → 2008-10-15 A (+2d) | 11d? → 12.56d? | 18% → 100% | 51.75d → none |  |  |
| 10 | Cambio en valores de Lista de Categorías y asociación grupos contactos | 2008-10-01 A | 2008-10-02 A |  | 0% → 100% | 0.71d → none |  |  |
| 11 | Pruebas y ajustes | 2008-10-03 A | 2008-10-03 A |  | 0% → 100% | 0.71d → none |  |  |
| 12 | Pruebas certificación por parte de Cines Unidos | 2008-10-06 A | 2008-10-09 A |  | 0% → 100% | 53.75d → none |  |  |
| 13 | Puesta en producción | 2008-10-10 → 2008-10-13 A (+3d) | 2008-10-10 → 2008-10-14 A (+4d) |  | 0% → 100% | 0.71d → none | 16 → 6 |  |
| 14 | Módulo de Contacto en producción | 2008-10-13 → 2008-10-14 A (+1d) | 2008-10-13 → 2008-10-15 A (+2d) |  | 0% → 100% | 51.75d → none |  |  |
| 15 | **Integración Sitio Web** | 2008-10-06 A | 2008-10-14 → 2008-10-09 A (-5d) | 7d? → 3.33d? | 0% → 100% | 0.71d → none |  |  |
| 16 | Ajustes | 2008-10-06 A | 2008-10-09 → 2008-10-08 A (-1d) | 4d? → 2.22d? | 0% → 100% | 0.71d → none |  | resources DS [50%] → DS2 [90%] |
| 17 | Implantación y pruebas en Pippin | 2008-10-13 → 2008-10-08 A (-5d) | 2008-10-14 → 2008-10-09 A (-5d) | 2d? → 1.11d? | 0% → 100% | 0.71d → none | 13 → 16 | resources DS [50%] → DS2 [90%] |
| 18 | **Integración Tiendas Cines Unidos** | 2008-10-10 → 2008-10-09 A (-1d) | 2008-10-20 → 2008-10-16 A (-4d) | 7d? → 5.62d? | 0% → 100% | 46.75d → none |  |  |
| 19 | Ajustes | 2008-10-10 → 2008-10-09 A (-1d) | 2008-10-16 → 2008-10-15 A (-1d) | 5d? → 3.75d? | 0% → 100% | 46.75d → none | 16 → 15 | resources DS2 [50%] → DS2 [80%] |
| 20 | Implantación y pruebas en Pippin | 2008-10-17 → 2008-10-15 A (-2d) | 2008-10-20 → 2008-10-16 A (-4d) | 2d? → 1.88d? | 0% → 100% | 46.75d → none |  | resources DS2 [50%] → DS2 [80%] |
| 21 | **Integración Transacciones** | 2008-10-15 → 2008-10-14 A (-1d) | 2008-10-24 → 2008-10-22 A (-2d) | 8d? → 5.56d? | 0% → 100% | 0.71d → none |  |  |
| 22 | Desarrollo | 2008-10-15 → 2008-10-14 A (-1d) | 2008-10-22 → 2008-10-20 A (-2d) | 6d? → 4.44d? | 0% → 100% | 0.71d → none | 15 → 13 | resources DS [50%] → DS [90%] |
| 23 | Implantación y Pruebas en Pippin | 2008-10-23 → 2008-10-21 A (-2d) | 2008-10-24 → 2008-10-22 A (-2d) | 2d? → 1.11d? | 0% → 100% | 0.71d → none |  | resources DS [50%] → DS [90%] |
| 24 | Documentación Diccionario de Datos Vista | 2008-10-03 → 2008-10-10 A (+7d) | 2008-10-03 → 2008-10-10 A (+7d) |  | 0% → 100% | 17.4d → none |  | constraint start no earlier than 2008-10-03 → start no earlier than 2008-10-10 |
| 25 | Integración Vista (Transacciones de Sitio Web) | 2008-10-27 → 2008-10-22 A (-5d) | 2008-11-18 → 2008-10-31 A (-18d) | 16.67d? → 6.94d? | 0% → 100% | 0.71d → none |  | resources DS [50%]; DS2 [30%] → DS [90%]; DS2 [90%] |
| 26 | Documentación Diccionario de Datos CC Vista | 2008-10-10 → 2008-10-17 (+7d) | 2008-10-10 → 2008-10-17 (+7d) |  |  | 29.07d → 9.35d |  | was named Documentación Diccionario de Datos Vista; constraint start no earlier than 2008-10-10 → start no earlier than 2008-10-17 |
| 27 | Integración CC-Vista (Clientes) | 2008-11-18 → 2008-10-31 (-18d) | 2008-12-11 → 2008-11-12 (-29d) | 16.67d? → 8.93d? |  | 0.71d → 9.57d |  | resources DS [50%]; DS2 [30%] → DS [90%]; DS2 [70%] |
| 28 | Documento Guia de Configuración de Integraciones | 2008-12-11 → 2008-11-12 A (-29d) | 2008-12-17 → 2008-11-17 (-30d) | 4d? → 2.22d? | 0% → 80% | 0.71d → 1.5d |  | resources DS [50%] → DS [90%] |
| 29 | Pruebas internas y Ajustes | 2008-12-17 → 2008-11-17 A (-30d) | 2009-01-19 → 2008-11-19 (-61d) | 4.71d → 1.88d | 0% → 80% | 0.71d → 6.29d |  | resources GP [10%]; DS [50%] → GP [10%]; DS [90%]; DS2 [80%] |
| 30 | Migración de Programas de Integración a Pippin (dir desarrollo) | 2009-01-19 → 2008-11-19 A (-61d) | 2009-01-21 → 2008-11-21 (-61d) |  | 0% → 80% | 0.71d → 4.69d |  |  |
| 31 | Preparación Pruebas de Certificación | 2009-01-21 → 2008-11-21 A (-61d) | 2009-01-26 → 2008-11-26 (-61d) |  | 0% → 80% | 0.71d → 0.29d |  |  |
| 32 | Apoyo en Pruebas de Certificación | 2009-01-26 → 2008-11-26 A (-61d) | 2009-02-02 → 2008-12-03 (-61d) |  | 0% → 20% | 4.71d → 6.29d |  |  |
| 33 | Pruebas de Certificación por parte de Cines Unidos | 2009-01-26 → 2008-11-26 A (-61d) | 2009-02-02 → 2008-12-03 (-61d) |  | 0% → 20% | 0.71d → 1.29d |  |  |
| 34 | Ajustes | 2009-02-02 → 2008-12-03 A (-61d) | 2009-02-04 → 2008-12-09 (-57d) | 2d? → 4d? | 0% → 20% | 0.71d → 0.49d |  |  |
| 35 | Verificación de Ajustes por parte de Cines Unidos | 2009-02-04 → 2008-12-09 A (-57d) | 2009-02-05 → 2008-12-10 (-57d) |  | 0% → 20% | 0.71d → 0.29d |  |  |
| 36 | Pase a Producción de Integraciones | 2009-02-05 → 2008-12-10 (-57d) | 2009-02-06 → 2008-12-11 (-57d) |  |  | 0.71d → 0.29d |  |  |
| 37 | CRM completo en Producción | 2009-02-06 → 2008-12-11 (-57d) | 2009-02-06 → 2008-12-11 (-57d) |  |  | 0.71d → 0.29d |  |  |
| 38 | Gerencia de Proyectos |  | 2009-02-06 → 2008-12-11 (-57d) | 66.25d → 42.88d | 20% → 98% |  |  | resources GP [10%] → GP [20%] |
